# NCSX VVSA for PPPL

Schedule from MS Project, 2004-07-22 to 2006-02-01, scheduled back from the finish.
Major Tool and Machine, Inc.

## Calendars

- Standard: Mon-Fri 08:00-12:00, 13:00-17:00; Sat-Sun off.

## Resources

| Resource |
| --- |
| 2 |
| 3 |
| 4 |
| 5 |

## Schedule

| ID | WBS | Task | Type | Duration | Start | Finish | Total slack | Free slack | Constraint | Text2 | Text1 |
| --- | --- | --- | --- | --- | --- | --- | --- | --- | --- | --- | --- |
| 1 | 1 | Submit Proposal | milestone | 0d | 2004-07-22 | 2004-07-22 | 0d |  | start no later than 2004-07-22 | 100 |  |
| 2 | 2 | Teleconference to discuss Proposal |  | 5d | 2004-07-26 | 2004-07-30 | 2d | 0d | start no later than 2004-07-26 | 100 |  |
| 3 | 3 | Receive Order | milestone | 0d | 2004-09-24 | 2004-09-24 | 47d | 0d | start no later than 2004-09-24 | 100 |  |
| 4 | 4 | **WO# 65678 PPPL VVSA Lot # 14** |  | 354d? | 2004-09-20 | 2006-01-26 | 42d | 0d | as late as possible |  |  |
| 5 | 4.1 | **Start Up/Engineering QLI#1** |  | 291d? | 2004-09-24 | 2005-11-04 | 46d | 0d | as late as possible |  |  |
| 6 | 4.1.1 | Process Order |  | 101d | 2004-12-31 | 2005-05-20 | 116d | 0d | finish no later than 2005-05-20 | 81 |  |
| 7 | 4.1.2 | Sect 5.1 Segmentation Scheme |  | 12d? | 2004-11-04 | 2004-11-19 | 75d | 0d | finish no later than 2004-11-19 | 100 | 75,000 |
| 8 | 4.1.3 | Sect 5.1.2 Fiducials | milestone | 1d? | 2005-11-04 | 2005-11-04 | 336d | 0d | finish no later than 2005-11-04 | 98 |  |
| 9 | 4.1.4 | Sect 5.1.3 Proc Outline & Asc Proc. |  | 156d? | 2004-09-24 | 2005-04-29 | 46d | 0d | start no later than 2004-09-24 | 95 | 95,000 |
| 10 | 4.2 | **Special Tooling QLI# 2** |  | 220d | 2004-09-20 | 2005-07-22 | 42d | 0d | as late as possible |  |  |
| 11 | 4.2.1 | **Dies & Gages Lot # 10** |  | 169d | 2004-09-20 | 2005-05-12 | 42d | 0d | as late as possible |  |  |
| 12 | 4.2.1.1 | Engineering |  | 95d | 2004-09-20 | 2005-01-28 | 42d | 0d | start no later than 2004-09-20 | 100 |  |
| 13 | 4.2.1.2 | Procure Materials |  | 17w | 2004-11-15 | 2005-03-11 | 82d | 0d | finish no later than 2005-03-13 | 100 | 315,000 |
| 14 | 4.2.1.3 | Machine Complete |  | 6.8w | 2005-02-21 | 2005-04-07 | 152d | 0d | start no later than 2005-02-21 | 100 |  |
| 15 | 4.2.1.4 | Deburr |  | 30d | 2005-02-28 | 2005-04-08 | 157d | 0d | start no later than 2005-02-28 | 85 |  |
| 16 | 4.2.1.5 | Inspection |  | 30d | 2005-03-01 | 2005-04-11 | 158d | 0d | finish no later than 2005-04-11 | 75 | 340,644 |
| 17 | 4.2.1.6 | Development Panels |  | 31d | 2005-03-31 | 2005-05-12 | 180d | 0d | finish no later than 2005-05-12 | 30 |  |
| 18 | 4.2.2 | **Fixtures (2) 60 degree Lot # 11** |  | 145d | 2004-10-25 | 2005-05-13 | 67d | 0d | as late as possible |  |  |
| 19 | 4.2.2.1 | Engineering |  | 95d | 2004-10-25 | 2005-03-04 | 67d | 0d | start no later than 2004-10-25 | 100 |  |
| 20 | 4.2.2.2 | Procure Materials |  | 3.6w | 2005-03-06 | 2005-03-30 | 162d | 0d | start no later than 2005-03-06 | 100 |  |
| 21 | 4.2.2.3 | Fab & Machine Complete |  | 5w | 2005-03-13 | 2005-04-15 | 167d | 0d | start no later than 2005-03-13 | 55 |  |
| 22 | 4.2.2.4 | Assemble |  | 5w | 2005-03-28 | 2005-04-29 | 177d | 0d | finish no later than 2005-04-30 | 10 |  |
| 23 | 4.2.2.5 | Deburr |  | 19d | 2005-04-12 | 2005-05-06 | 188d | 0d | finish no later than 2005-05-07 |  |  |
| 24 | 4.2.2.6 | Inspection |  | 16d | 2005-04-22 | 2005-05-13 | 196d | 0d | finish no later than 2005-05-14 |  |  |

| ID | WBS | Task | Duration | Start | Finish | Total slack | Free slack | Constraint | Text2 | Text1 | Text3 | Text4 | Text5 |
| --- | --- | --- | --- | --- | --- | --- | --- | --- | --- | --- | --- | --- | --- |
| 25 | 4.2.3 | **Fixture (3) 120 degree Lot # 12** | 125d | 2005-01-31 | 2005-07-22 | 137d | 0d | as late as possible |  |  |  |  |  |
| 26 | 4.2.3.1 | Engineering | 70d | 2005-01-31 | 2005-05-06 | 137d | 0d | finish no later than 2005-05-06 | 30 |  |  |  |  |
| 27 | 4.2.3.2 | Procure Materials | 11d | 2005-04-29 | 2005-05-13 | 201d | 0d | start no later than 2005-04-29 |  | 220,000 |  |  |  |
| 28 | 4.2.3.3 | Fab & Machine Complete | 30d | 2005-05-13 | 2005-06-23 | 211d | 0d | start no later than 2005-05-13 |  |  |  |  |  |
| 29 | 4.2.3.4 | Assemble | 46d | 2005-05-20 | 2005-07-22 | 216d | 0d | start no later than 2005-05-20 |  |  |  |  |  |
| 30 | 4.2.3.5 | Deburr | 9d | 2005-07-04 | 2005-07-14 | 247d | 0d | finish no later than 2005-07-14 |  |  |  |  |  |
| 31 | 4.2.3.6 | Inspection | 9d | 2005-07-04 | 2005-07-14 | 247d | 0d | finish no later than 2005-07-14 |  |  | 120 #2 | 120 #3 | First |
| 32 | 4.3 | Procure Vessel Material | 126d | 2004-10-29 | 2005-04-22 | 71d | 0d | start no later than 2004-10-29 | 90 | 390,000 |  |  |  |
| 33 | 4.4 | Production Panels Period #1 Lot # 4 | 22d | 2005-04-22 | 2005-05-23 | 196d | 0d | finish no later than 2005-05-23 |  | 260,000 |  |  |  |
| 34 | 4.5 | Production Panels Period #2 Lot # 5 | 24d | 2005-05-24 | 2005-06-24 | 218d | 0d | finish no later than 2005-06-24 |  | 240,000 |  |  |  |
| 35 | 4.6 | Production Panels Period #3 Lot # 6 | 27d | 2005-05-30 | 2005-07-05 | 222d | 0d | finish no later than 2005-07-05 |  | 240,000 |  |  |  |
| 36 | 4.7 | Port Ext,Misc Hardware Period #1 Lot # 7 | 80d | 2005-03-23 | 2005-07-12 | 174d | 0d | finish no later than 2005-07-12 | 10 |  |  |  |  |
| 37 | 4.8 | Port Ext,Misc Hardware Period # 2 Lot # 8 | 105d | 2005-03-23 | 2005-08-16 | 174d | 0d | finish no later than 2005-08-16 | 10 |  |  |  |  |
| 38 | 4.9 | Port Ext,Misc Hardware Period #4 Lot # 9 | 125d | 2005-03-23 | 2005-09-13 | 174d | 0d | finish no later than 2005-09-13 | 10 |  |  |  |  |
| 39 | 4.10 | (1) Spacer (3) Port Ext. Fixtures Lot # 13 | 75d | 2005-06-06 | 2005-09-16 | 227d | 0d | finish no later than 2005-09-18 |  |  |  |  |  |
| 40 | 4.11 | **First 120 deg seg QLI #3 Lot # 1** | 142d | 2005-05-02 | 2005-11-15 | 202d | 0d | as late as possible |  |  |  |  |  |
| 41 | 4.11.1 | 1st 60 deg segment | 31d | 2005-05-02 | 2005-06-13 | 202d | 0d | finish no later than 2005-06-13 |  |  |  |  |  |
| 42 | 4.11.2 | 2nd 60 deg segment | 35d | 2005-05-23 | 2005-07-08 | 217d | 0d | finish no later than 2005-07-10 |  |  |  |  |  |
| 43 | 4.11.3 | Join two pieces | 17d | 2005-07-10 | 2005-08-02 | 252d | 0d | start no later than 2005-07-10 |  | 400,000 |  |  |  |
| 44 | 4.11.4 | Machine for Ports | 12d | 2005-08-03 | 2005-08-18 | 269d | 0d | finish no later than 2005-08-18 |  |  |  |  |  |
| 45 | 4.11.5 | Weld Ports | 22d | 2005-08-18 | 2005-09-16 | 280d | 0d | finish no later than 2005-09-16 |  |  |  |  |  |
| 46 | 4.11.6 | Final Machine | 15d | 2005-09-19 | 2005-10-07 | 302d | 0d | finish no later than 2005-10-09 |  |  |  |  |  |
| 47 | 4.11.7 | Vacuum Test | 10d | 2005-10-10 | 2005-10-21 | 317d | 0d | finish no later than 2005-10-23 |  |  |  |  |  |
| 48 | 4.11.8 | Cut Off Ports | 10d | 2005-10-24 | 2005-11-04 | 327d | 0d | finish no later than 2005-11-04 |  |  |  |  |  |
| 49 | 4.11.9 | Pack for Shipping #1 | 5d | 2005-11-07 | 2005-11-11 | 337d | 0d | finish no later than 2005-11-11 |  |  |  |  |  |
| 50 | 4.11.10 | Receive at PPPL | 2d | 2005-11-14 | 2005-11-15 | 342d | 0d | finish no later than 2005-11-15 |  | 375,560 |  |  |  |

| ID | WBS | Task | Duration | Start | Finish | Total slack | Free slack | Constraint | Text1 |
| --- | --- | --- | --- | --- | --- | --- | --- | --- | --- |
| 51 | 4.12 | **Second 120 deg seg QLI# 3 Lot # 2** | 130d | 2005-06-24 | 2005-12-22 | 241d | 0d | as late as possible |  |
| 52 | 4.12.1 | 60 deg segment | 21d | 2005-06-24 | 2005-07-22 | 241d | 0d | finish no later than 2005-07-24 |  |
| 53 | 4.12.2 | 60 deg segment | 20d | 2005-07-25 | 2005-08-19 | 262d | 0d | finish no later than 2005-08-20 |  |
| 54 | 4.12.3 | Join two pieces | 11d | 2005-08-22 | 2005-09-05 | 282d | 0d | finish no later than 2005-09-05 | 405,000 |
| 55 | 4.12.4 | Machine for Ports | 15d | 2005-09-05 | 2005-09-23 | 292d | 0d | finish no later than 2005-09-25 |  |
| 56 | 4.12.5 | Weld Ports | 20d | 2005-09-26 | 2005-10-21 | 307d | 0d | finish no later than 2005-10-23 |  |
| 57 | 4.12.6 | Final Machine | 15d | 2005-10-24 | 2005-11-11 | 327d | 0d | finish no later than 2005-11-13 |  |
| 58 | 4.12.7 | Vacuum Test | 10d | 2005-11-14 | 2005-11-25 | 342d | 0d | finish no later than 2005-11-27 |  |
| 59 | 4.12.8 | Cut Off Ports | 10d | 2005-11-28 | 2005-12-09 | 352d | 0d | finish no later than 2005-12-11 |  |
| 60 | 4.12.9 | Pack for Shipping #2 | 5d | 2005-12-12 | 2005-12-16 | 362d | 0d | finish no later than 2005-12-17 |  |
| 61 | 4.12.10 | Receive at PPPL | 4d | 2005-12-19 | 2005-12-22 | 367d | 0d | finish no later than 2005-12-22 | 375,000 |
| 62 | 4.13 | **Third 120 deg seg QLI# 3 Lot # 3** | 129d | 2005-08-01 | 2006-01-26 | 267d | 0d | as late as possible |  |
| 63 | 4.13.1 | 60 deg segment | 20d | 2005-08-01 | 2005-08-26 | 267d | 0d | finish no later than 2005-08-28 |  |
| 64 | 4.13.2 | 60 deg segment | 20d | 2005-09-04 | 2005-09-30 | 292d | 0d | start no later than 2005-09-04 |  |
| 65 | 4.13.3 | Join two pieces | 11d | 2005-10-03 | 2005-10-17 | 312d | 0d | finish no later than 2005-10-17 | 375,000 |
| 66 | 4.13.4 | Machine for Ports | 10d | 2005-10-17 | 2005-10-28 | 322d | 0d | finish no later than 2005-10-30 |  |
| 67 | 4.13.5 | Weld Ports | 15d | 2005-10-31 | 2005-11-18 | 332d | 0d | finish no later than 2005-11-20 |  |
| 68 | 4.13.6 | Final Machine | 10d | 2005-11-21 | 2005-12-02 | 347d | 0d | finish no later than 2005-12-04 |  |
| 69 | 4.13.7 | Vacuum Test | 10d | 2005-12-05 | 2005-12-16 | 357d | 0d | finish no later than 2005-12-18 |  |
| 70 | 4.13.8 | Cut Off Ports | 9d | 2006-01-05 | 2006-01-17 | 380d | 0d | finish no later than 2006-01-17 |  |
| 71 | 4.13.9 | Pack for Shipping #3 | 4d | 2006-01-17 | 2006-01-20 | 388d | 0d | finish no later than 2006-01-20 |  |
| 72 | 4.13.10 | Receive at PPPL | 4d | 2006-01-23 | 2006-01-26 | 392d | 0d | finish no later than 2006-01-26 | 375,000 |
| 73 | 5 | Pack for PPPL - Tooling | 5d? | 2006-01-23 | 2006-01-27 | 392d | 0d | finish no later than 2006-01-29 |  |
| 74 | 6 | Receive at PPPL - Tooling | 3d? | 2006-01-30 | 2006-02-01 | 397d | 0d | finish no later than 2006-02-01 | 486,000 |
