# NCSX VVSA for PPPL

Schedule from MS Project, 1999-01-01 to 2006-02-01, scheduled back from the finish.
Major Tool and Machine, Inc.

## Calendars

- Standard: Mon-Fri 08:00-12:00, 13:00-17:00; Sat-Sun off.

## Resources

| Resource |
| --- |
| 2 |
| 3 |
| 4 |
| 5 |

## Schedule

| ID | WBS | Task | Type | Duration | Start | Finish | Total slack | Free slack | Constraint | Text2 | Text1 |
| --- | --- | --- | --- | --- | --- | --- | --- | --- | --- | --- | --- |
| 1 | 1 | Submit Proposal | milestone | 0d | 2004-07-22 | 2004-07-22 | 1449d | 0d | start no later than 2004-07-22 | 100 |  |
| 2 | 2 | Teleconference to discuss Proposal |  | 5d | 2004-07-26 | 2004-07-30 | 2d | 0d | start no later than 2004-07-26 | 100 |  |
| 3 | 3 | Receive Order | milestone | 0d | 2004-09-24 | 2004-09-24 | 47d | 0d | start no later than 2004-09-24 | 100 |  |
| 4 | 4 | **WO# 65678 PPPL VVSA Lot # 14** |  | 1845d? | 1999-01-01 | 2006-01-26 | 0d |  | as late as possible |  |  |
| 5 | 4.1 | **Start Up/Engineering QLI#1** |  | 291d? | 2004-09-24 | 2005-11-04 | 1495d | 0d | as late as possible |  |  |
| 6 | 4.1.1 | Process Order |  | 171d | 2004-09-24 | 2005-05-20 | 46d | 0d | start no later than 2004-09-24 | 100 |  |
| 7 | 4.1.2 | Sect 5.1 Segmentation Scheme |  | 12d? | 2004-11-04 | 2004-11-19 | 75d | 0d | finish no later than 2004-11-19 | 100 | 75,000 |
| 8 | 4.1.3 | Sect 5.1.2 Fiducials | milestone | 1d? | 2005-11-04 | 2005-11-04 | 336d | 0d | finish no later than 2005-11-04 | 98 |  |
| 9 | 4.1.4 | Sect 5.1.3 Proc Outline & Asc Proc. |  | 156d? | 2004-09-24 | 2005-04-29 | 46d | 0d | start no later than 2004-09-24 | 100 | 95,000 |
| 10 | 4.2 | **Special Tooling QLI# 2** |  | 220d | 2004-09-20 | 2005-07-22 | 1491d | 0d | as late as possible |  |  |
| 11 | 4.2.1 | **Dies & Gages Lot # 10** |  | 169d | 2004-09-20 | 2005-05-12 | 1491d | 0d | as late as possible |  |  |
| 12 | 4.2.1.1 | Engineering |  | 95d | 2004-09-20 | 2005-01-28 | 42d | 0d | start no later than 2004-09-20 | 100 |  |
| 13 | 4.2.1.2 | Procure Materials |  | 17w | 2004-11-15 | 2005-03-11 | 82d | 0d | finish no later than 2005-03-13 | 100 | 315,000 |
| 14 | 4.2.1.3 | Machine Complete |  | 6.8w | 2005-02-21 | 2005-04-07 | 152d | 0d | start no later than 2005-02-21 | 100 |  |
| 15 | 4.2.1.4 | Deburr |  | 30d | 2005-02-28 | 2005-04-08 | 157d | 0d | start no later than 2005-02-28 | 100 |  |
| 16 | 4.2.1.5 | Inspection |  | 30d | 2005-03-01 | 2005-04-11 | 158d | 0d | finish no later than 2005-04-11 | 100 | 340,644 |
| 17 | 4.2.1.6 | Development Panels |  | 31d | 2005-03-31 | 2005-05-12 | 180d | 0d | finish no later than 2005-05-12 | 100 |  |
| 18 | 4.2.2 | **Fixtures (2) 60 degree Lot # 11** |  | 145d | 2004-10-25 | 2005-05-13 | 1516d | 0d | as late as possible |  |  |
| 19 | 4.2.2.1 | Engineering |  | 95d | 2004-10-25 | 2005-03-04 | 67d | 0d | start no later than 2004-10-25 | 100 |  |
| 20 | 4.2.2.2 | Procure Materials |  | 3.6w | 2005-03-06 | 2005-03-30 | 162d | 0d | start no later than 2005-03-06 | 100 |  |
| 21 | 4.2.2.3 | Fab & Machine Complete |  | 5w | 2005-03-13 | 2005-04-15 | 167d | 0d | start no later than 2005-03-13 | 100 |  |
| 22 | 4.2.2.4 | Assemble |  | 5w | 2005-03-28 | 2005-04-29 | 177d | 0d | finish no later than 2005-04-30 | 100 |  |
| 23 | 4.2.2.5 | Deburr |  | 19d | 2005-04-12 | 2005-05-06 | 188d | 0d | finish no later than 2005-05-07 | 100 |  |
| 24 | 4.2.2.6 | Inspection |  | 16d | 2005-04-22 | 2005-05-13 | 196d | 0d | finish no later than 2005-05-14 | 100 |  |

| ID | WBS | Task | Duration | Start | Finish | Total slack | Free slack | Constraint | Text2 | Text1 | Text3 | Text5 |
| --- | --- | --- | --- | --- | --- | --- | --- | --- | --- | --- | --- | --- |
| 25 | 4.2.3 | **Fixture (3) 120 degree Lot # 12** | 125d | 2005-01-31 | 2005-07-22 | 1586d | 0d | as late as possible |  |  |  |  |
| 26 | 4.2.3.1 | Engineering | 70d | 2005-01-31 | 2005-05-06 | 137d | 0d | finish no later than 2005-05-06 | 100 |  |  |  |
| 27 | 4.2.3.2 | Procure Materials | 11d | 2005-04-29 | 2005-05-13 | 201d | 0d | start no later than 2005-04-29 | 100 | 220,000 |  |  |
| 28 | 4.2.3.3 | Fab & Machine Complete | 30d | 2005-05-13 | 2005-06-23 | 211d | 0d | start no later than 2005-05-13 | 100 |  |  |  |
| 29 | 4.2.3.4 | Assemble | 46d | 2005-05-20 | 2005-07-22 | 216d | 0d | start no later than 2005-05-20 | 100 |  |  |  |
| 30 | 4.2.3.5 | Deburr | 9d | 2005-07-04 | 2005-07-14 | 247d | 0d | finish no later than 2005-07-14 | 100 |  |  |  |
| 31 | 4.2.3.6 | Inspection | 9d | 2005-07-04 | 2005-07-14 | 247d | 0d | finish no later than 2005-07-14 | 100 |  | 120 #2 Complete | 120 Fixture Complete |
| 32 | 4.3 | Procure Vessel Material | 126d | 2004-10-29 | 2005-04-22 | 71d | 0d | start no later than 2004-10-29 | 100 | 390,000 |  |  |
| 33 | 4.4 | Production Panels Period #1 Lot # 4 | 22d | 2005-04-22 | 2005-05-23 | 196d | 0d | finish no later than 2005-05-23 | 100 | 260,000 |  |  |
| 34 | 4.5 | Production Panels Period #2 Lot # 5 | 24d | 2005-05-24 | 2005-06-24 | 218d | 0d | finish no later than 2005-06-24 | 100 | 240,000 |  |  |
| 35 | 4.6 | Production Panels Period #3 Lot # 6 | 27d | 2005-05-30 | 2005-07-05 | 222d | 0d | finish no later than 2005-07-05 | 100 | 240,000 |  |  |
| 36 | 4.7 | Port Ext,Misc Hardware Period #1 Lot # 7 | 80d | 2005-03-23 | 2005-07-12 | 174d | 0d | finish no later than 2005-07-12 | 80 |  |  |  |
| 37 | 4.8 | Port Ext,Misc Hardware Period # 2 Lot # 8 | 105d | 2005-03-23 | 2005-08-16 | 1623d | 0d | finish no later than 2005-08-16 | 60 |  |  |  |
| 38 | 4.9 | Port Ext,Misc Hardware Period # 3 Lot # 9 | 125d | 2005-03-23 | 2005-09-13 | 1623d | 0d | finish no later than 2005-09-13 | 50 |  |  |  |
| 39 | 4.10 | (1) Spacer (3) Port Ext. Fixtures Lot # 13 | 75d | 2005-06-06 | 2005-09-16 | 1676d | 0d | finish no later than 2005-09-18 | 95 |  |  |  |
| 40 | 4.11 | **First 120 deg seg QLI #3 Lot # 1** | 1793d? | 1999-01-01 | 2005-11-15 | 0d |  | as late as possible |  |  |  |  |
| 41 | 4.11.1 | 1st 60 deg segment | 31d | 2005-05-02 | 2005-06-13 | 202d | 0d | finish no later than 2005-06-13 | 100 |  |  |  |
| 42 | 4.11.2 | 2nd 60 deg segment | 35d | 2005-05-23 | 2005-07-08 | 217d | 0d | finish no later than 2005-07-10 | 100 |  |  |  |
| 43 | 4.11.3 | Join two pieces | 17d | 2005-07-10 | 2005-08-02 | 252d | 0d | start no later than 2005-07-10 | 100 | 400,000 |  |  |
| 44 | 4.11.4 | Machine for Ports | 12d | 2005-08-03 | 2005-08-18 | 269d | 0d | finish no later than 2005-08-18 | 100 |  |  |  |
| 45 | 4.11.5 | Weld Ports | 22d | 2005-08-18 | 2005-09-16 | 1729d | 0d | finish no later than 2005-09-16 |  |  |  |  |
| 46 | 4.11.6 | Vacuum Test | 10d | 2005-10-10 | 2005-10-21 | 1766d | 0d | finish no later than 2005-10-23 |  |  |  |  |
| 47 | 4.11.7 | Cut Off Ports | 10d | 2005-10-24 | 2005-11-04 | 1776d | 0d | finish no later than 2005-11-04 |  |  |  |  |
| 48 | 4.11.8 | Final Machine (moved was B4 V Test) | 15d | 2005-09-19 | 2005-10-07 | 1751d | 0d | finish no later than 2005-10-09 |  |  |  |  |
| 49 | 4.11.9 | Final Inspection (New) | 1d? | 1999-01-01 | 1999-01-01 | 0d |  | finish no later than 1999-01-01 |  |  |  |  |
| 50 | 4.11.10 | Pack for Shipping #1 | 5d | 2005-11-07 | 2005-11-11 | 1786d | 0d | finish no later than 2005-11-11 |  |  |  |  |
| 51 | 4.11.11 | Receive at PPPL | 2d | 2005-11-14 | 2005-11-15 | 1791d | 0d | finish no later than 2005-11-15 |  | 375,560 |  |  |

| ID | WBS | Task | Duration | Start | Finish | Total slack | Free slack | Constraint | Text2 | Text1 |
| --- | --- | --- | --- | --- | --- | --- | --- | --- | --- | --- |
| 52 | 4.12 | **Second 120 deg seg QLI# 3 Lot # 2** | 1820d? | 1999-01-01 | 2005-12-22 | 0d |  | as late as possible |  |  |
| 53 | 4.12.1 | 60 deg segment | 21d | 2005-06-24 | 2005-07-22 | 1690d | 0d | finish no later than 2005-07-24 | 100 |  |
| 54 | 4.12.2 | 60 deg segment | 20d | 2005-07-25 | 2005-08-19 | 1711d | 0d | finish no later than 2005-08-20 | 95 |  |
| 55 | 4.12.3 | Join two pieces | 11d | 2005-08-22 | 2005-09-05 | 1731d | 0d | finish no later than 2005-09-05 | 10 | 405,000 |
| 56 | 4.12.4 | Machine for Ports | 15d | 2005-09-05 | 2005-09-23 | 1741d | 0d | finish no later than 2005-09-25 |  |  |
| 57 | 4.12.5 | Weld Ports | 20d | 2005-09-26 | 2005-10-21 | 1756d | 0d | finish no later than 2005-10-23 |  |  |
| 58 | 4.12.6 | Vacuum Test | 10d | 2005-11-14 | 2005-11-25 | 1791d | 0d | finish no later than 2005-11-27 |  |  |
| 59 | 4.12.7 | Cut Off Ports | 10d | 2005-11-28 | 2005-12-09 | 1801d | 0d | finish no later than 2005-12-11 |  |  |
| 60 | 4.12.8 | Final Machine (moved was B4 V Test) | 15d | 2005-10-24 | 2005-11-11 | 1776d | 0d | finish no later than 2005-11-13 |  |  |
| 61 | 4.12.9 | Final Inspection (New) | 1d? | 1999-01-01 | 1999-01-01 | 0d |  | finish no later than 1999-01-01 |  |  |
| 62 | 4.12.10 | Pack for Shipping #2 | 5d | 2005-12-12 | 2005-12-16 | 1811d | 0d | finish no later than 2005-12-17 |  |  |
| 63 | 4.12.11 | Receive at PPPL | 4d | 2005-12-19 | 2005-12-22 | 1816d | 0d | finish no later than 2005-12-22 |  | 375,000 |
| 64 | 4.13 | **Third 120 deg seg QLI# 3 Lot # 3** | 1845d? | 1999-01-01 | 2006-01-26 | 0d |  | as late as possible |  |  |
| 65 | 4.13.1 | 60 deg segment | 20d | 2005-08-01 | 2005-08-26 | 1716d | 0d | finish no later than 2005-08-28 | 15 |  |
| 66 | 4.13.2 | 60 deg segment | 20d | 2005-09-04 | 2005-09-30 | 1741d | 0d | start no later than 2005-09-04 |  |  |
| 67 | 4.13.3 | Join two pieces | 11d | 2005-10-03 | 2005-10-17 | 1761d | 0d | finish no later than 2005-10-17 |  | 375,000 |
| 68 | 4.13.4 | Machine for Ports | 10d | 2005-10-17 | 2005-10-28 | 1771d | 0d | finish no later than 2005-10-30 |  |  |
| 69 | 4.13.5 | Weld Ports | 15d | 2005-10-31 | 2005-11-18 | 1781d | 0d | finish no later than 2005-11-20 |  |  |
| 70 | 4.13.6 | Vacuum Test | 10d | 2005-12-05 | 2005-12-16 | 1806d | 0d | finish no later than 2005-12-18 |  |  |
| 71 | 4.13.7 | Cut Off Ports | 9d | 2006-01-05 | 2006-01-17 | 1829d | 0d | finish no later than 2006-01-17 |  |  |
| 72 | 4.13.8 | Final Machine (moved was B4 V Test) | 10d | 2005-11-21 | 2005-12-02 | 1796d | 0d | finish no later than 2005-12-04 |  |  |
| 73 | 4.13.9 | Final Inspection (New) | 1d? | 1999-01-01 | 1999-01-01 | 0d |  | finish no later than 1999-01-01 |  |  |
| 74 | 4.13.10 | Pack for Shipping #3 | 4d | 2006-01-17 | 2006-01-20 | 1837d | 0d | finish no later than 2006-01-20 |  |  |
| 75 | 4.13.11 | Receive at PPPL | 4d | 2006-01-23 | 2006-01-26 | 1841d | 0d | finish no later than 2006-01-26 |  | 375,000 |
| 76 | 5 | Pack for PPPL - Tooling | 5d? | 2006-01-23 | 2006-01-27 | 1841d | 0d | finish no later than 2006-01-29 |  |  |
| 77 | 6 | Receive at PPPL - Tooling | 3d? | 2006-01-30 | 2006-02-01 | 1846d | 0d | finish no later than 2006-02-01 |  | 486,000 |
