# NCSX VVSA for PPPL

Schedule from MS Project, 1999-01-01 to 2006-02-01, scheduled back from the finish.
Major Tool and Machine, Inc.

## Calendars

- Standard: Mon-Fri 08:00-12:00, 13:00-17:00; Sat-Sun off.

## Resources

| Resource |
| --- |
| 2 |
| 3 |
| 4 |
| 5 |

## Schedule

| ID | WBS | Task | Type | Duration | Start | Finish | Total slack | Free slack | Constraint | Text2 | Text1 |
| --- | --- | --- | --- | --- | --- | --- | --- | --- | --- | --- | --- |
| 1 | 1 | Submit Proposal | milestone | 0d | 2004-07-22 | 2004-07-22 | 1449d | 0d | start no later than 2004-07-22 | 100 |  |
| 2 | 2 | Teleconference to discuss Proposal |  | 5d | 2004-07-26 | 2004-07-30 | 1451d | 0d | start no later than 2004-07-26 | 100 |  |
| 3 | 3 | Receive Order | milestone | 0d | 2004-09-24 | 2004-09-24 | 1496d | 0d | start no later than 2004-09-24 | 100 |  |
| 4 | 4 | **WO# 65678 PPPL VVSA Lot # 14** |  | 1845d? | 1999-01-01 | 2006-01-26 | 0d |  | as late as possible |  |  |
| 5 | 4.1 | **Start Up/Engineering QLI#1** |  | 291d? | 2004-09-24 | 2005-11-04 | 1495d | 0d | as late as possible |  |  |
| 6 | 4.1.1 | Process Order |  | 171d | 2004-09-24 | 2005-05-20 | 1495d | 0d | start no later than 2004-09-24 | 100 |  |
| 7 | 4.1.2 | Sect 5.1 Segmentation Scheme |  | 12d? | 2004-11-04 | 2004-11-19 | 1524d | 0d | finish no later than 2004-11-19 | 100 | 75,000 |
| 8 | 4.1.3 | Sect 5.1.2 Fiducials |  | 1d? | 2005-11-04 | 2005-11-04 | 1785d | 0d | finish no later than 2005-11-04 | 98 |  |
| 9 | 4.1.4 | Sect 5.1.3 Proc Outline & Asc Proc. |  | 156d? | 2004-09-24 | 2005-04-29 | 1495d | 0d | start no later than 2004-09-24 | 100 | 95,000 |
| 10 | 4.2 | **Special Tooling QLI# 2** |  | 220d | 2004-09-20 | 2005-07-22 | 1491d | 0d | as late as possible |  |  |
| 11 | 4.2.1 | **Dies & Gages Lot # 10** |  | 169d | 2004-09-20 | 2005-05-12 | 1491d | 0d | as late as possible |  |  |
| 12 | 4.2.1.1 | Engineering |  | 95d | 2004-09-20 | 2005-01-28 | 1491d | 0d | start no later than 2004-09-20 | 100 |  |
| 13 | 4.2.1.2 | Procure Materials |  | 17w | 2004-11-15 | 2005-03-11 | 1531d | 0d | finish no later than 2005-03-13 | 100 | 315,000 |
| 14 | 4.2.1.3 | Machine Complete |  | 6.8w | 2005-02-21 | 2005-04-07 | 1601d | 0d | start no later than 2005-02-21 | 100 |  |
| 15 | 4.2.1.4 | Deburr |  | 30d | 2005-02-28 | 2005-04-08 | 1606d | 0d | start no later than 2005-02-28 | 100 |  |
| 16 | 4.2.1.5 | Inspection |  | 30d | 2005-03-01 | 2005-04-11 | 1607d | 0d | finish no later than 2005-04-11 | 100 | 340,644 |
| 17 | 4.2.1.6 | Development Panels |  | 31d | 2005-03-31 | 2005-05-12 | 1629d | 0d | finish no later than 2005-05-12 | 100 |  |
| 18 | 4.2.2 | **Fixtures (2) 60 degree Lot # 11** |  | 145d | 2004-10-25 | 2005-05-13 | 1516d | 0d | as late as possible |  |  |
| 19 | 4.2.2.1 | Engineering |  | 95d | 2004-10-25 | 2005-03-04 | 1516d | 0d | start no later than 2004-10-25 | 100 |  |
| 20 | 4.2.2.2 | Procure Materials |  | 3.6w | 2005-03-06 | 2005-03-30 | 1611d | 0d | start no later than 2005-03-06 | 100 |  |
| 21 | 4.2.2.3 | Fab & Machine Complete |  | 5w | 2005-03-13 | 2005-04-15 | 1616d | 0d | start no later than 2005-03-13 | 100 |  |
| 22 | 4.2.2.4 | Assemble |  | 5w | 2005-03-28 | 2005-04-29 | 1626d | 0d | finish no later than 2005-04-30 | 100 |  |
| 23 | 4.2.2.5 | Deburr |  | 19d | 2005-04-12 | 2005-05-06 | 1637d | 0d | finish no later than 2005-05-07 | 100 |  |
| 24 | 4.2.2.6 | Inspection |  | 16d | 2005-04-22 | 2005-05-13 | 1645d | 0d | finish no later than 2005-05-14 | 100 |  |

| ID | WBS | Task | Type | Duration | Start | Finish | Total slack | Free slack | Constraint | Text2 | Text1 | Text3 | Text5 |
| --- | --- | --- | --- | --- | --- | --- | --- | --- | --- | --- | --- | --- | --- |
| 25 | 4.2.3 | **Fixture (3) 120 degree Lot # 12** |  | 125d | 2005-01-31 | 2005-07-22 | 1586d | 0d | as late as possible |  |  |  |  |
| 26 | 4.2.3.1 | Engineering |  | 70d | 2005-01-31 | 2005-05-06 | 1586d | 0d | finish no later than 2005-05-06 | 100 |  |  |  |
| 27 | 4.2.3.2 | Procure Materials |  | 11d | 2005-04-29 | 2005-05-13 | 1650d | 0d | start no later than 2005-04-29 | 100 | 220,000 |  |  |
| 28 | 4.2.3.3 | Fab & Machine Complete |  | 30d | 2005-05-13 | 2005-06-23 | 1660d | 0d | start no later than 2005-05-13 | 100 |  |  |  |
| 29 | 4.2.3.4 | Assemble |  | 46d | 2005-05-20 | 2005-07-22 | 1665d | 0d | start no later than 2005-05-20 | 100 |  |  |  |
| 30 | 4.2.3.5 | Deburr |  | 9d | 2005-07-04 | 2005-07-14 | 1696d | 0d | finish no later than 2005-07-14 | 100 |  |  |  |
| 31 | 4.2.3.6 | Inspection |  | 9d | 2005-07-04 | 2005-07-14 | 1696d | 0d | finish no later than 2005-07-14 | 100 |  | 120 #2 Complete | 120 Fixture Complete |
| 32 | 4.3 | Procure Vessel Material |  | 126d | 2004-10-29 | 2005-04-22 | 1520d | 0d | start no later than 2004-10-29 | 100 | 390,000 |  |  |
| 33 | 4.4 | Production Panels Period #1 Lot # 4 |  | 22d | 2005-04-22 | 2005-05-23 | 1645d | 0d | finish no later than 2005-05-23 | 100 | 260,000 |  |  |
| 34 | 4.5 | Production Panels Period #2 Lot # 5 |  | 24d | 2005-05-24 | 2005-06-24 | 1667d | 0d | finish no later than 2005-06-24 | 100 | 240,000 |  |  |
| 35 | 4.6 | Production Panels Period #3 Lot # 6 |  | 27d | 2005-05-30 | 2005-07-05 | 1671d | 0d | finish no later than 2005-07-05 | 100 | 240,000 |  |  |
| 36 | 4.7 | Port Ext,Misc Hardware Period #1 Lot # 7 |  | 80d | 2005-03-23 | 2005-07-12 | 1623d | 0d | finish no later than 2005-07-12 | 100 |  |  |  |
| 37 | 4.8 | Port Ext,Misc Hardware Period # 2 Lot # 8 |  | 105d | 2005-03-23 | 2005-08-16 | 1623d | 0d | finish no later than 2005-08-16 | 100 |  |  |  |
| 38 | 4.9 | Port Ext,Misc Hardware Period # 3 Lot # 9 |  | 125d | 2005-03-23 | 2005-09-13 | 1623d | 0d | finish no later than 2005-09-13 | 100 |  |  |  |
| 39 | 4.10 | (1) Spacer (3) Port Ext. Fixtures Lot # 13 |  | 75d | 2005-06-06 | 2005-09-16 | 1676d | 0d | finish no later than 2005-09-18 | 100 |  |  |  |
| 40 | 4.11 | **First 120 deg seg QLI #3 Lot # 1** |  | 1793d? | 1999-01-01 | 2005-11-15 | 0d |  | as late as possible |  |  |  |  |
| 41 | 4.11.1 | 1st 60 deg segment |  | 31d | 2005-05-02 | 2005-06-13 | 1651d | 0d | finish no later than 2005-06-13 | 100 |  |  |  |
| 42 | 4.11.2 | 2nd 60 deg segment |  | 35d | 2005-05-23 | 2005-07-08 | 1666d | 0d | finish no later than 2005-07-10 | 100 |  |  |  |
| 43 | 4.11.3 | Join two pieces |  | 17d | 2005-07-10 | 2005-08-02 | 1701d | 0d | start no later than 2005-07-10 | 100 | 400,000 |  |  |
| 44 | 4.11.4 | Machine for Ports |  | 12d | 2005-08-03 | 2005-08-18 | 1718d | 0d | finish no later than 2005-08-18 | 100 |  |  |  |
| 45 | 4.11.5 | **Weld Ports** |  | 1d? | 1999-01-01 | 1999-01-01 | 0d |  | as late as possible |  |  |  |  |
| 46 | 4.11.5.1 | Round Ports (less dome ports) |  | 1d? | 1999-01-01 | 1999-01-01 | 0d |  | start no later than 1999-01-01 | 100 |  |  |  |
| 47 | 4.11.5.2 | Dome Ports 17 & 18 | milestone | 0d? | 1999-01-01 | 1999-01-01 | 1d | 0d | finish no later than 1999-01-01 | 100 |  |  |  |
| 48 | 4.11.5.3 | (8) Bosses | milestone | 0d? | 1999-01-01 | 1999-01-01 | 1d | 0d | finish no later than 1999-01-01 | 100 |  |  |  |
| 49 | 4.11.5.4 | 100% Laser Scan Layout and Weld Flanges | milestone | 0d? | 1999-01-01 | 1999-01-01 | 1d | 0d | finish no later than 1999-01-01 | 100 |  |  |  |
| 50 | 4.11.5.5 | Polish and Rough Clean Interior | milestone | 0d? | 1999-01-01 | 1999-01-01 | 1d | 0d | finish no later than 1999-01-01 | 100 |  |  |  |
| 51 | 4.11.5.6 | Weld on Spacer and Covers | milestone | 0d? | 1999-01-01 | 1999-01-01 | 1d | 0d | finish no later than 1999-01-01 | 100 |  |  |  |

| ID | WBS | Task | Type | Duration | Start | Finish | Total slack | Free slack | Constraint | Text2 | Text1 |
| --- | --- | --- | --- | --- | --- | --- | --- | --- | --- | --- | --- |
| 52 | 4.11.6 | **Vacuum Test** |  | 1d | 1999-01-01 | 1999-01-01 | 0d |  | as late as possible |  |  |
| 53 | 4.11.6.1 | First Vacuum Test |  | 1d | 1999-01-01 | 1999-01-01 | 0d |  | finish no later than 1999-01-01 | 100 |  |
| 54 | 4.11.6.2 | Heat Blankets |  | 1d | 1999-01-01 | 1999-01-01 | 0d |  | finish no later than 1999-01-01 | 100 |  |
| 55 | 4.11.6.3 | Thermal Cycle |  | 1d | 1999-01-01 | 1999-01-01 | 0d |  | finish no later than 1999-01-01 | 100 |  |
| 56 | 4.11.6.4 | Final Vacuum Test |  | 1d | 1999-01-01 | 1999-01-01 | 0d |  | finish no later than 1999-01-01 | 100 |  |
| 57 | 4.11.6.5 | Laser check after Vacuum Test |  | 1d | 1999-01-01 | 1999-01-01 | 0d |  | finish no later than 1999-01-01 | 100 |  |
| 58 | 4.11.7 | Cut Off Ports |  | 10d | 2005-10-24 | 2005-11-04 | 1776d | 0d | finish no later than 2005-11-04 | 100 |  |
| 59 | 4.11.8 | Final Machine |  | 15d | 2005-09-19 | 2005-10-07 | 1751d | 0d | finish no later than 2005-10-09 |  |  |
| 60 | 4.11.9 | Tack on Ports, weld on tube and block (NEW) |  | 1d? | 1999-01-01 | 1999-01-01 | 0d |  | finish no later than 1999-01-01 |  |  |
| 61 | 4.11.10 | Final Inspection |  | 1d? | 1999-01-01 | 1999-01-01 | 0d |  | finish no later than 1999-01-01 |  |  |
| 62 | 4.11.11 | Pack for Shipping #1 |  | 5d | 2005-11-07 | 2005-11-11 | 1786d | 0d | finish no later than 2005-11-11 |  |  |
| 63 | 4.11.12 | Receive at PPPL |  | 2d | 2005-11-14 | 2005-11-15 | 1791d | 0d | finish no later than 2005-11-15 |  | 375,560 |
| 64 | 4.12 | **Second 120 deg seg QLI# 3 Lot # 2** |  | 1820d? | 1999-01-01 | 2005-12-22 | 0d |  | as late as possible |  |  |
| 65 | 4.12.1 | 60 deg segment |  | 21d | 2005-06-24 | 2005-07-22 | 1690d | 0d | finish no later than 2005-07-24 | 100 |  |
| 66 | 4.12.2 | 60 deg segment |  | 20d | 2005-07-25 | 2005-08-19 | 1711d | 0d | finish no later than 2005-08-20 | 100 |  |
| 67 | 4.12.3 | Join two pieces |  | 11d | 2005-08-22 | 2005-09-05 | 1731d | 0d | finish no later than 2005-09-05 | 100 | 405,000 |
| 68 | 4.12.4 | Machine for Ports |  | 15d | 2005-09-05 | 2005-09-23 | 1741d | 0d | finish no later than 2005-09-25 | 100 |  |
| 69 | 4.12.5 | **Weld Ports** |  | 1d? | 1999-01-01 | 1999-01-01 | 0d |  | as late as possible |  |  |
| 70 | 4.12.5.1 | NB Port |  | 1d? | 1999-01-01 | 1999-01-01 | 0d |  | finish no later than 1999-01-01 | 100 |  |
| 71 | 4.12.5.2 | Port 4 |  | 1d? | 1999-01-01 | 1999-01-01 | 0d |  | finish no later than 1999-01-01 | 100 |  |
| 72 | 4.12.5.3 | Port 12 |  | 1d? | 1999-01-01 | 1999-01-01 | 0d |  | finish no later than 1999-01-01 | 100 |  |
| 73 | 4.12.5.4 | Domes |  | 1d? | 1999-01-01 | 1999-01-01 | 0d |  | finish no later than 1999-01-01 | 100 |  |
| 74 | 4.12.5.5 | Round Ports (less dome ports) |  | 1d? | 1999-01-01 | 1999-01-01 | 0d |  | start no later than 1999-01-01 | 100 |  |
| 75 | 4.12.5.6 | Dome Ports 17 & 18 | milestone | 0d? | 1999-01-01 | 1999-01-01 | 1d | 0d | finish no later than 1999-01-01 | 100 |  |
| 76 | 4.12.5.7 | (8) Bosses | milestone | 0d? | 1999-01-01 | 1999-01-01 | 1d | 0d | finish no later than 1999-01-01 | 10 |  |
| 77 | 4.12.5.8 | 100% Laser Scan Layout and Weld Flanges | milestone | 0d? | 1999-01-01 | 1999-01-01 | 1d | 0d | finish no later than 1999-01-01 |  |  |
| 78 | 4.12.5.9 | Polish and Rough Clean Interior | milestone | 0d? | 1999-01-01 | 1999-01-01 | 1d | 0d | finish no later than 1999-01-01 |  |  |
| 79 | 4.12.5.10 | Weld on Spacer and Covers | milestone | 0d? | 1999-01-01 | 1999-01-01 | 1d | 0d | finish no later than 1999-01-01 |  |  |

| ID | WBS | Task | Type | Duration | Start | Finish | Total slack | Free slack | Constraint | Text1 | Text2 |
| --- | --- | --- | --- | --- | --- | --- | --- | --- | --- | --- | --- |
| 80 | 4.12.6 | **Vacuum Test** |  | 1d | 1999-01-01 | 1999-01-01 | 0d |  | as late as possible |  |  |
| 81 | 4.12.6.1 | First Vacuum Test |  | 1d | 1999-01-01 | 1999-01-01 | 0d |  | finish no later than 1999-01-01 |  |  |
| 82 | 4.12.6.2 | Heat Blankets (deleted) |  | 1d | 1999-01-01 | 1999-01-01 | 0d |  | finish no later than 1999-01-01 |  |  |
| 83 | 4.12.6.3 | Thermal Cycle (deleted) |  | 1d | 1999-01-01 | 1999-01-01 | 0d |  | finish no later than 1999-01-01 |  |  |
| 84 | 4.12.6.4 | Final Vacuum Test |  | 1d | 1999-01-01 | 1999-01-01 | 0d |  | finish no later than 1999-01-01 |  |  |
| 85 | 4.12.6.5 | Laser check after Vacuum Test |  | 1d | 1999-01-01 | 1999-01-01 | 0d |  | finish no later than 1999-01-01 |  |  |
| 86 | 4.12.7 | Cut Off Ports |  | 10d | 2005-11-28 | 2005-12-09 | 1801d | 0d | finish no later than 2005-12-11 |  |  |
| 87 | 4.12.8 | Final Machine |  | 15d | 2005-10-24 | 2005-11-11 | 1776d | 0d | finish no later than 2005-11-13 |  |  |
| 88 | 4.12.9 | Tack on Ports, weld on tube and block (NEW) |  | 1d? | 1999-01-01 | 1999-01-01 | 0d |  | finish no later than 1999-01-01 |  |  |
| 89 | 4.12.10 | Final Inspection |  | 1d? | 1999-01-01 | 1999-01-01 | 0d |  | finish no later than 1999-01-01 |  |  |
| 90 | 4.12.11 | Pack for Shipping #2 |  | 5d | 2005-12-12 | 2005-12-16 | 1811d | 0d | finish no later than 2005-12-17 |  |  |
| 91 | 4.12.12 | Receive at PPPL |  | 4d | 2005-12-19 | 2005-12-22 | 1816d | 0d | finish no later than 2005-12-22 | 375,000 |  |
| 92 | 4.13 | **Third 120 deg seg QLI# 3 Lot # 3** |  | 1845d? | 1999-01-01 | 2006-01-26 | 0d |  | as late as possible |  |  |
| 93 | 4.13.1 | 60 deg segment |  | 20d | 2005-08-01 | 2005-08-26 | 1716d | 0d | finish no later than 2005-08-28 |  | 100 |
| 94 | 4.13.2 | 60 deg segment |  | 20d | 2005-09-04 | 2005-09-30 | 1741d | 0d | start no later than 2005-09-04 |  | 100 |
| 95 | 4.13.3 | Join two pieces |  | 35d | 2005-10-03 | 2005-11-18 | 1761d | 0d | finish no later than 2005-11-18 | 375,000 | 100 |
| 96 | 4.13.4 | Machine for Ports |  | 10d | 2005-10-17 | 2005-10-28 | 1771d | 0d | finish no later than 2005-10-30 |  |  |
| 97 | 4.13.5 | **Weld Ports** |  | 1d? | 1999-01-01 | 1999-01-01 | 0d |  | as late as possible |  |  |
| 98 | 4.13.5.1 | NB |  | 1d? | 1999-01-01 | 1999-01-01 | 0d |  | finish no later than 1999-01-01 |  |  |
| 99 | 4.13.5.2 | Port 4 |  | 1d? | 1999-01-01 | 1999-01-01 | 0d |  | finish no later than 1999-01-01 |  |  |
| 100 | 4.13.5.3 | Port 12 |  | 1d? | 1999-01-01 | 1999-01-01 | 0d |  | finish no later than 1999-01-01 |  |  |
| 101 | 4.13.5.4 | Domes |  | 1d? | 1999-01-01 | 1999-01-01 | 0d |  | finish no later than 1999-01-01 |  |  |
| 102 | 4.13.5.5 | Round Ports (less dome ports) |  | 1d? | 1999-01-01 | 1999-01-01 | 0d |  | start no later than 1999-01-01 |  |  |
| 103 | 4.13.5.6 | Dome Ports 17 & 18 | milestone | 0d? | 1999-01-01 | 1999-01-01 | 1d | 0d | finish no later than 1999-01-01 |  |  |
| 104 | 4.13.5.7 | (8) Bosses | milestone | 0d? | 1999-01-01 | 1999-01-01 | 1d | 0d | finish no later than 1999-01-01 |  |  |
| 105 | 4.13.5.8 | 100% Laser Scan Layout and Weld Flanges | milestone | 0d? | 1999-01-01 | 1999-01-01 | 1d | 0d | finish no later than 1999-01-01 |  |  |
| 106 | 4.13.5.9 | Polish and Rough Clean Interior | milestone | 0d? | 1999-01-01 | 1999-01-01 | 1d | 0d | finish no later than 1999-01-01 |  |  |
| 107 | 4.13.5.10 | Weld on Spacer and Covers | milestone | 0d? | 1999-01-01 | 1999-01-01 | 1d | 0d | finish no later than 1999-01-01 |  |  |

| ID | WBS | Task | Duration | Start | Finish | Total slack | Free slack | Constraint | Text1 |
| --- | --- | --- | --- | --- | --- | --- | --- | --- | --- |
| 108 | 4.13.6 | **Vacuum Test** | 1d | 1999-01-01 | 1999-01-01 | 0d |  | as late as possible |  |
| 109 | 4.13.6.1 | First Vacuum Test | 1d | 1999-01-01 | 1999-01-01 | 0d |  | finish no later than 1999-01-01 |  |
| 110 | 4.13.6.2 | Heat Blankets (deleted) | 1d | 1999-01-01 | 1999-01-01 | 0d |  | finish no later than 1999-01-01 |  |
| 111 | 4.13.6.3 | Thermal Cycle (deleted) | 1d | 1999-01-01 | 1999-01-01 | 0d |  | finish no later than 1999-01-01 |  |
| 112 | 4.13.6.4 | Final Vacuum Test | 1d | 1999-01-01 | 1999-01-01 | 0d |  | finish no later than 1999-01-01 |  |
| 113 | 4.13.6.5 | Laser check after Vacuum Test | 1d | 1999-01-01 | 1999-01-01 | 0d |  | finish no later than 1999-01-01 |  |
| 114 | 4.13.7 | Cut Off Ports | 9d | 2006-01-05 | 2006-01-17 | 1829d | 0d | finish no later than 2006-01-17 |  |
| 115 | 4.13.8 | Final Machine | 10d | 2005-11-21 | 2005-12-02 | 1796d | 0d | finish no later than 2005-12-04 |  |
| 116 | 4.13.9 | Tack on Ports, weld on tube and block (NEW) | 1d? | 1999-01-01 | 1999-01-01 | 0d |  | finish no later than 1999-01-01 |  |
| 117 | 4.13.10 | Final Inspection | 1d? | 1999-01-01 | 1999-01-01 | 0d |  | finish no later than 1999-01-01 |  |
| 118 | 4.13.11 | Pack for Shipping #3 | 4d | 2006-01-17 | 2006-01-20 | 1837d | 0d | finish no later than 2006-01-20 |  |
| 119 | 4.13.12 | Receive at PPPL | 4d | 2006-01-23 | 2006-01-26 | 1841d | 0d | finish no later than 2006-01-26 | 375,000 |
| 120 | 5 | **Tooling Deliveries** | 8d? | 2006-01-23 | 2006-02-01 | 1841d | 0d | as late as possible |  |
| 121 | 5.1 | Pack for PPPL - Tooling | 5d? | 2006-01-23 | 2006-01-27 | 1841d | 0d | finish no later than 2006-01-29 |  |
| 122 | 5.2 | Receive at PPPL - Tooling | 3d? | 2006-01-30 | 2006-02-01 | 1846d | 0d | finish no later than 2006-02-01 | 486,000 |
