# NCSX VVSA for PPPL

Schedule from MS Project, 2004-07-22 to 2005-12-01, scheduled back from the finish.
Major Tool and Machine, Inc.

## Calendars

- Standard: Mon-Fri 08:00-12:00, 13:00-17:00; Sat-Sun off.

## Resources

| Resource |
| --- |
| 2 |
| 3 |
| 4 |
| 5 |

## Schedule

| ID | WBS | Task | Type | Duration | Start | Finish | Total slack | Free slack | Constraint | Text2 | Text1 |
| --- | --- | --- | --- | --- | --- | --- | --- | --- | --- | --- | --- |
| 1 | 1 | Submit Proposal | milestone | 0d | 2004-07-22 | 2004-07-22 | 0d |  | start no later than 2004-07-22 | 100 |  |
| 2 | 2 | Teleconference to discuss Proposal |  | 5d | 2004-07-26 | 2004-07-30 | 2d | 0d | start no later than 2004-07-26 | 100 |  |
| 3 | 3 | Receive Order | milestone | 0d | 2004-09-24 | 2004-09-24 | 47d | 0d | start no later than 2004-09-24 | 100 |  |
| 4 | 4 | **WO# 65678 PPPL VVSA Lot # 14** |  | 319d? | 2004-09-02 | 2005-11-22 | 30d | 0d | as late as possible |  |  |
| 5 | 4.1 | **Start Up/Engineering QLI#1** |  | 70d? | 2004-09-24 | 2004-12-30 | 46d | 0d | as late as possible |  |  |
| 6 | 4.1.1 | Process Order |  | 70d | 2004-09-24 | 2004-12-30 | 46d | 0d | finish no later than 2004-12-30 | 60 |  |
| 7 | 4.1.2 | Sect 5.1 Segmentation Scheme |  | 12d? | 2004-11-04 | 2004-11-19 | 75d | 0d | finish no later than 2004-11-19 | 100 | 75 |
| 8 | 4.1.3 | Sect 5.1.2 Fiducials |  | 15d? | 2004-11-29 | 2004-12-17 | 92d | 0d | finish no later than 2004-12-17 |  | 55 |
| 9 | 4.1.4 | Sect 5.1.3 Proc Outline & Asc Procedures |  | 56d? | 2004-09-24 | 2004-12-10 | 46d | 0d | finish no later than 2004-12-10 | 75 | 95 |
| 10 | 4.2 | **Special Tooling QLI# 2** |  | 187d | 2004-09-02 | 2005-05-20 | 30d | 0d | as late as possible |  |  |
| 11 | 4.2.1 | **Dies & Gages Lot # 10** |  | 127d | 2004-09-02 | 2005-02-25 | 30d | 0d | as late as possible |  |  |
| 12 | 4.2.1.1 | Engineering |  | 65d | 2004-09-02 | 2004-12-01 | 30d | 0d | finish no later than 2004-12-01 | 70 |  |
| 13 | 4.2.1.2 | Procure Materials (4 sets) |  | 8w | 2004-11-15 | 2005-01-07 | 82d | 0d | finish no later than 2005-01-07 |  | 215 |
| 14 | 4.2.1.3 | Machine Complete |  | 8.6w | 2004-12-01 | 2005-01-28 | 94d | 0d | finish no later than 2005-01-28 |  |  |
| 15 | 4.2.1.4 | Deburr |  | 41d | 2004-12-10 | 2005-02-04 | 101d | 0d | finish no later than 2005-02-04 |  |  |
| 16 | 4.2.1.5 | Inspection |  | 41d | 2004-12-17 | 2005-02-11 | 106d | 0d | finish no later than 2005-02-11 |  | 239 |
| 17 | 4.2.1.6 | Development Panels |  | 45d | 2004-12-27 | 2005-02-25 | 112d | 0d | finish no later than 2005-02-25 |  |  |
| 18 | 4.2.2 | **Fixtures (2) 60 degree Lot # 11** |  | 98d | 2004-10-25 | 2005-03-09 | 67d | 0d | as late as possible |  |  |
| 19 | 4.2.2.1 | Engineering |  | 40d | 2004-10-25 | 2004-12-17 | 67d | 0d | finish no later than 2004-12-17 | 85 |  |
| 20 | 4.2.2.2 | Procure Materials |  | 4.2w | 2004-12-17 | 2005-01-14 | 106d | 0d | finish no later than 2005-01-14 |  |  |
| 21 | 4.2.2.3 | Fab & Machine Complete |  | 5w | 2005-01-14 | 2005-02-17 | 126d | 0d | finish no later than 2005-02-18 |  |  |
| 22 | 4.2.2.4 | Assemble |  | 1w | 2005-02-18 | 2005-02-24 | 151d | 0d | start no later than 2005-02-18 |  |  |
| 23 | 4.2.2.5 | Deburr |  | 5d | 2005-02-25 | 2005-03-03 | 156d | 0d | start no later than 2005-02-25 |  |  |
| 24 | 4.2.2.6 | Inspection |  | 4d | 2005-03-04 | 2005-03-09 | 161d | 0d | start no later than 2005-03-04 |  |  |

| ID | WBS | Task | Duration | Start | Finish | Total slack | Free slack | Constraint | Text1 | Text2 |
| --- | --- | --- | --- | --- | --- | --- | --- | --- | --- | --- |
| 25 | 4.2.3 | **Fixture (3) 120 degree Lot # 12** | 97d | 2005-01-06 | 2005-05-20 | 120d | 0d | as late as possible |  |  |
| 26 | 4.2.3.1 | Engineering | 15d | 2005-01-06 | 2005-01-26 | 120d | 0d | finish no later than 2005-01-26 |  |  |
| 27 | 4.2.3.2 | Procure Materials | 13d | 2005-01-19 | 2005-02-04 | 129d | 0d | start no later than 2005-01-19 | 220 |  |
| 28 | 4.2.3.3 | Fab & Machine Complete | 58d | 2005-02-07 | 2005-04-27 | 142d | 0d | finish no later than 2005-04-28 |  |  |
| 29 | 4.2.3.4 | Assemble | 5d | 2005-04-28 | 2005-05-04 | 200d | 0d | start no later than 2005-04-28 |  |  |
| 30 | 4.2.3.5 | Deburr | 6d | 2005-05-05 | 2005-05-12 | 205d | 0d | start no later than 2005-05-05 |  |  |
| 31 | 4.2.3.6 | Inspection | 6d | 2005-05-13 | 2005-05-20 | 211d | 0d | start no later than 2005-05-13 |  |  |
| 32 | 4.3 | Procure Vessel Material | 86d | 2004-10-29 | 2005-02-25 | 71d | 0d | finish no later than 2005-02-25 | 290 | 55 |
| 33 | 4.4 | Production Panels Period #1 Lot # 4 | 42d | 2005-02-25 | 2005-04-26 | 157d | 0d | start no later than 2005-02-25 | 260 |  |
| 34 | 4.5 | Production Panels Period #2 Lot # 5 | 31d | 2005-04-22 | 2005-06-03 | 196d | 0d | finish no later than 2005-06-03 | 200 |  |
| 35 | 4.6 | Production Panels Period #3 Lot # 6 | 30d | 2005-05-17 | 2005-06-28 | 214d | 0d | start no later than 2005-05-17 | 200 |  |
| 36 | 4.7 | Port Ext,Misc Hardware Period #1 Lot # 7 | 62d | 2005-04-11 | 2005-07-05 | 187d | 0d | start no later than 2005-04-11 |  |  |
| 37 | 4.8 | Port Ext,Misc Hardware Period # 2 Lot # 8 | 52d | 2005-05-30 | 2005-08-09 | 222d | 0d | start no later than 2005-05-30 |  |  |
| 38 | 4.9 | Port Ext,Misc Hardware Period #4 Lot # 9 | 52d | 2005-06-27 | 2005-09-06 | 242d | 0d | start no later than 2005-06-27 |  |  |
| 39 | 4.10 | (1) Spacer (3) Port Ext. Fixtures Lot # 13 | 76d | 2005-02-17 | 2005-06-03 | 151d | 0d | start no later than 2005-02-17 |  |  |
| 40 | 4.11 | **First 120 deg seg QLI #3 Lot # 1** | 147d | 2005-03-29 | 2005-10-19 | 178d | 0d | as late as possible |  |  |
| 41 | 4.11.1 | 1st 60 deg segment | 31d | 2005-03-29 | 2005-05-10 | 178d | 0d | finish no later than 2005-05-10 |  |  |
| 42 | 4.11.2 | 2nd 60 deg segment | 24d | 2005-05-03 | 2005-06-03 | 203d | 0d | finish no later than 2005-06-03 |  |  |
| 43 | 4.11.3 | Join two pieces | 17d | 2005-05-22 | 2005-06-14 | 217d | 0d | start no later than 2005-05-22 | 350 |  |
| 44 | 4.11.4 | Machine for Ports | 15d | 2005-06-14 | 2005-07-05 | 234d | 0d | start no later than 2005-06-14 |  |  |
| 45 | 4.11.5 | Weld Ports | 30d | 2005-07-05 | 2005-08-16 | 249d | 0d | start no later than 2005-07-05 |  |  |
| 46 | 4.11.6 | Final Machine | 15d | 2005-08-16 | 2005-09-06 | 279d | 0d | start no later than 2005-08-16 |  |  |
| 47 | 4.11.7 | Vacuum Test | 10d | 2005-09-06 | 2005-09-20 | 294d | 0d | start no later than 2005-09-06 |  |  |
| 48 | 4.11.8 | Cut Off Ports | 15d | 2005-09-20 | 2005-10-11 | 304d | 0d | start no later than 2005-09-20 |  |  |
| 49 | 4.11.9 | Pack for Shipping #1 | 3d | 2005-10-11 | 2005-10-14 | 319d | 0d | start no later than 2005-10-11 |  |  |
| 50 | 4.11.10 | Receive at PPPL | 3d | 2005-10-14 | 2005-10-19 | 322d | 0d | start no later than 2005-10-14 | 375.56 |  |

| ID | WBS | Task | Duration | Start | Finish | Total slack | Free slack | Constraint | Text1 |
| --- | --- | --- | --- | --- | --- | --- | --- | --- | --- |
| 51 | 4.12 | **Second 120 deg seg QLI# 3 Lot # 2** | 106d | 2005-06-03 | 2005-10-31 | 227d | 0d | as late as possible |  |
| 52 | 4.12.1 | 60 deg segment | 20d | 2005-06-03 | 2005-07-01 | 227d | 0d | start no later than 2005-06-03 |  |
| 53 | 4.12.2 | 60 deg segment | 20d | 2005-06-14 | 2005-07-12 | 234d | 0d | start no later than 2005-06-14 |  |
| 54 | 4.12.3 | Join two pieces | 10d | 2005-07-05 | 2005-07-19 | 249d | 0d | start no later than 2005-07-05 | 350 |
| 55 | 4.12.4 | Machine for Ports | 15d | 2005-07-19 | 2005-08-09 | 259d | 0d | start no later than 2005-07-19 |  |
| 56 | 4.12.5 | Weld Ports | 20d | 2005-08-09 | 2005-09-06 | 274d | 0d | start no later than 2005-08-09 |  |
| 57 | 4.12.6 | Final Machine | 15d | 2005-09-06 | 2005-09-27 | 294d | 0d | start no later than 2005-09-06 |  |
| 58 | 4.12.7 | Vacuum Test | 10d | 2005-09-27 | 2005-10-11 | 309d | 0d | start no later than 2005-09-27 |  |
| 59 | 4.12.8 | Cut Off Ports | 10d | 2005-10-07 | 2005-10-21 | 317d | 0d | start no later than 2005-10-07 |  |
| 60 | 4.12.9 | Pack for Shipping #2 | 4d | 2005-10-21 | 2005-10-27 | 327d | 0d | start no later than 2005-10-21 |  |
| 61 | 4.12.10 | Receive at PPPL | 2d | 2005-10-27 | 2005-10-31 | 331d | 0d | start no later than 2005-10-27 | 375 |
| 62 | 4.13 | **Third 120 deg seg QLI# 3 Lot # 3** | 103d | 2005-07-01 | 2005-11-22 | 246d | 0d | as late as possible |  |
| 63 | 4.13.1 | 60 deg segment | 21d | 2005-07-01 | 2005-07-29 | 246d | 0d | finish no later than 2005-07-29 |  |
| 64 | 4.13.2 | 60 deg segment | 20d | 2005-07-17 | 2005-08-12 | 257d | 0d | start no later than 2005-07-17 |  |
| 65 | 4.13.3 | Join two pieces | 10d | 2005-08-09 | 2005-08-23 | 274d | 0d | start no later than 2005-08-09 | 375 |
| 66 | 4.13.4 | Machine for Ports | 10d | 2005-08-23 | 2005-09-06 | 284d | 0d | start no later than 2005-08-23 |  |
| 67 | 4.13.5 | Weld Ports | 15d | 2005-09-06 | 2005-09-27 | 294d | 0d | start no later than 2005-09-06 |  |
| 68 | 4.13.6 | Final Machine | 10d | 2005-09-27 | 2005-10-11 | 309d | 0d | start no later than 2005-09-27 |  |
| 69 | 4.13.7 | Vacuum Test | 10d | 2005-10-11 | 2005-10-25 | 319d | 0d | start no later than 2005-10-11 |  |
| 70 | 4.13.8 | Cut Off Ports | 15d | 2005-10-25 | 2005-11-15 | 329d | 0d | start no later than 2005-10-25 |  |
| 71 | 4.13.9 | Pack for Shipping #3 | 3d | 2005-11-15 | 2005-11-18 | 344d | 0d | start no later than 2005-11-15 |  |
| 72 | 4.13.10 | Receive at PPPL | 2d | 2005-11-18 | 2005-11-22 | 347d | 0d | start no later than 2005-11-18 | 375 |
| 73 | 5 | Pack for PPPL Tooling | 5d? | 2005-11-18 | 2005-11-25 | 347d | 0d | start no later than 2005-11-18 |  |
| 74 | 6 | Receive at PPPL Tooling | 4d? | 2005-11-28 | 2005-12-01 | 352d | 0d | finish no later than 2005-12-01 | 486 |
