# NCSX VVSA for PPPL

Schedule from MS Project, 2004-07-22 to 2006-01-06, scheduled back from the finish.
Major Tool and Machine, Inc.

## Calendars

- Standard: Mon-Fri 08:00-12:00, 13:00-17:00; Sat-Sun off.

## Resources

| Resource |
| --- |
| 2 |
| 3 |
| 4 |
| 5 |

## Schedule

| ID | WBS | Task | Type | Duration | Start | Finish | Total slack | Free slack | Constraint | Text2 | Text1 | Text3 | Text4 |
| --- | --- | --- | --- | --- | --- | --- | --- | --- | --- | --- | --- | --- | --- |
| 1 | 1 | Submit Proposal | milestone | 0d | 2004-07-22 | 2004-07-22 | 0d |  | start no later than 2004-07-22 | 100 |  |  |  |
| 2 | 2 | Teleconference to discuss Proposal |  | 5d | 2004-07-26 | 2004-07-30 | 2d | 0d | start no later than 2004-07-26 | 100 |  |  |  |
| 3 | 3 | Receive Order | milestone | 0d | 2004-09-24 | 2004-09-24 | 47d | 0d | start no later than 2004-09-24 | 100 |  |  |  |
| 4 | 4 | **WO# 65678 PPPL VVSA Lot # 14** |  | 336d? | 2004-09-24 | 2006-01-06 | 46d | 0d | as late as possible |  |  |  |  |
| 5 | 4.1 | **Start Up/Engineering QLI#1** |  | 147d? | 2004-09-24 | 2005-04-18 | 46d | 0d | as late as possible |  |  |  |  |
| 6 | 4.1.1 | Process Order |  | 147d | 2004-09-24 | 2005-04-18 | 46d | 0d | start no later than 2004-09-24 | 60 |  |  |  |
| 7 | 4.1.2 | Sect 5.1 Segmentation Scheme |  | 12d? | 2004-11-04 | 2004-11-19 | 75d | 0d | finish no later than 2004-11-19 | 100 | 75 |  |  |
| 8 | 4.1.3 | Sect 5.1.2 Fiducials |  | 40d? | 2004-12-13 | 2005-02-04 | 102d | 0d | start no later than 2004-12-13 | 95 | 55 |  |  |
| 9 | 4.1.4 | Sect 5.1.3 Proc Outline & Asc Procedures |  | 116d? | 2004-09-24 | 2005-03-04 | 46d | 0d | start no later than 2004-09-24 | 80 | 95 |  |  |
| 10 | 4.2 | **Special Tooling QLI# 2** |  | 162d | 2004-12-02 | 2005-07-15 | 95d | 0d | as late as possible |  |  |  |  |
| 11 | 4.2.1 | **Dies & Gages Lot # 10** |  | 97d | 2004-12-02 | 2005-04-15 | 95d | 0d | as late as possible |  |  |  |  |
| 12 | 4.2.1.1 | Engineering |  | 42d | 2004-12-02 | 2005-01-28 | 95d | 0d | finish no later than 2005-01-28 | 100 |  |  |  |
| 13 | 4.2.1.2 | Procure Materials (10 sets was 4) |  | 8.6w | 2005-01-10 | 2005-03-09 | 122d | 0d | finish no later than 2005-03-09 | 60 | 215 |  |  |
| 14 | 4.2.1.3 | Machine Complete |  | 6.6w | 2005-02-07 | 2005-03-23 | 142d | 0d | start no later than 2005-02-07 |  |  |  |  |
| 15 | 4.2.1.4 | Deburr |  | 23d | 2005-02-24 | 2005-03-28 | 155d | 0d | start no later than 2005-02-24 |  |  |  |  |
| 16 | 4.2.1.5 | Inspection |  | 24d | 2005-02-25 | 2005-03-30 | 156d | 0d | start no later than 2005-02-25 |  | 239 |  |  |
| 17 | 4.2.1.6 | Development Panels |  | 35d | 2005-02-28 | 2005-04-15 | 157d | 0d | start no later than 2005-02-28 |  |  |  |  |
| 18 | 4.2.2 | **Fixtures (2) 60 degree Lot # 11** |  | 91d | 2004-12-17 | 2005-04-22 | 106d | 0d | as late as possible |  |  |  |  |
| 19 | 4.2.2.1 | Engineering |  | 39d | 2004-12-17 | 2005-02-09 | 106d | 0d | finish no later than 2005-02-09 | 90 |  |  |  |
| 20 | 4.2.2.2 | Procure Materials |  | 1.8w | 2005-02-07 | 2005-02-17 | 142d | 0d | finish no later than 2005-02-18 |  |  |  |  |
| 21 | 4.2.2.3 | Fab & Machine Complete |  | 5.2w | 2005-02-18 | 2005-03-25 | 151d | 0d | finish no later than 2005-03-26 |  |  |  |  |
| 22 | 4.2.2.4 | Assemble |  | 4.4w | 2005-03-22 | 2005-04-20 | 173d | 0d | finish no later than 2005-04-20 |  |  |  |  |
| 23 | 4.2.2.5 | Deburr |  | 21d | 2005-03-25 | 2005-04-22 | 176d | 0d | start no later than 2005-03-25 |  |  |  |  |
| 24 | 4.2.2.6 | Inspection |  | 2d | 2005-03-28 | 2005-03-29 | 177d | 0d | finish no later than 2005-03-29 |  |  | First | Second 60 Deg Fixture |

| ID | WBS | Task | Duration | Start | Finish | Total slack | Free slack | Constraint | Text2 | Text1 | Text3 | Text4 | Text5 |
| --- | --- | --- | --- | --- | --- | --- | --- | --- | --- | --- | --- | --- | --- |
| 25 | 4.2.3 | **Fixture (3) 120 degree Lot # 12** | 120d | 2005-01-30 | 2005-07-15 | 137d | 0d | as late as possible |  |  |  |  |  |
| 26 | 4.2.3.1 | Engineering | 55d | 2005-01-30 | 2005-04-15 | 137d | 0d | start no later than 2005-01-30 | 10 |  |  |  |  |
| 27 | 4.2.3.2 | Procure Materials | 50d | 2005-02-21 | 2005-04-29 | 152d | 0d | finish no later than 2005-04-29 |  | 220 |  |  |  |
| 28 | 4.2.3.3 | Fab & Machine Complete | 60d | 2005-04-01 | 2005-06-23 | 181d | 0d | start no later than 2005-04-01 |  |  |  |  |  |
| 29 | 4.2.3.4 | Assemble | 47d | 2005-05-04 | 2005-07-08 | 205d | 0d | start no later than 2005-05-04 |  |  |  |  |  |
| 30 | 4.2.3.5 | Deburr | 46d | 2005-05-12 | 2005-07-15 | 211d | 0d | start no later than 2005-05-12 |  |  |  |  |  |
| 31 | 4.2.3.6 | Inspection | 3d | 2005-05-18 | 2005-05-20 | 214d | 0d | start no later than 2005-05-18 |  |  | Milling | Port Weld (3) 120 Deg Fixtures | 60 to 60 |
| 32 | 4.3 | Procure Vessel Material | 102d | 2004-10-29 | 2005-03-21 | 71d | 0d | finish no later than 2005-03-22 | 65 | 290 |  |  |  |
| 33 | 4.4 | Production Panels Period #1 Lot # 4 | 30d | 2005-03-22 | 2005-05-02 | 173d | 0d | finish no later than 2005-05-03 |  | 260 |  |  |  |
| 34 | 4.5 | Production Panels Period #2 Lot # 5 | 31d | 2005-04-22 | 2005-06-03 | 196d | 0d | finish no later than 2005-06-03 |  | 200 |  |  |  |
| 35 | 4.6 | Production Panels Period #3 Lot # 6 | 30d | 2005-05-17 | 2005-06-28 | 214d | 0d | start no later than 2005-05-17 |  | 200 |  |  |  |
| 36 | 4.7 | Port Ext,Misc Hardware Period #1 Lot # 7 | 62d | 2005-04-11 | 2005-07-05 | 187d | 0d | finish no later than 2005-07-05 |  |  |  |  |  |
| 37 | 4.8 | Port Ext,Misc Hardware Period # 2 Lot # 8 | 52d | 2005-05-30 | 2005-08-09 | 222d | 0d | start no later than 2005-05-30 |  |  |  |  |  |
| 38 | 4.9 | Port Ext,Misc Hardware Period #4 Lot # 9 | 52d | 2005-06-27 | 2005-09-06 | 242d | 0d | start no later than 2005-06-27 |  |  |  |  |  |
| 39 | 4.10 | (0) Spacers (3) Port Ext. Fixtures Lot # 13 | 56d | 2005-04-15 | 2005-07-01 | 191d | 0d | finish no later than 2005-07-01 |  |  |  |  |  |
| 40 | 4.11 | **First 120 deg seg QLI #3 Lot # 1** | 147d | 2005-03-29 | 2005-10-19 | 178d | 0d | as late as possible |  |  |  |  |  |
| 41 | 4.11.1 | 1st 60 deg segment | 31d | 2005-03-29 | 2005-05-10 | 178d | 0d | finish no later than 2005-05-10 |  |  |  |  |  |
| 42 | 4.11.2 | 2nd 60 deg segment | 24d | 2005-05-03 | 2005-06-03 | 203d | 0d | finish no later than 2005-06-03 |  |  |  |  |  |
| 43 | 4.11.3 | Join two pieces | 20d | 2005-05-20 | 2005-06-16 | 216d | 0d | finish no later than 2005-06-17 |  | 350 |  |  |  |
| 44 | 4.11.4 | Machine for Ports | 22d | 2005-06-17 | 2005-07-18 | 236d | 0d | finish no later than 2005-07-18 |  |  |  |  |  |
| 45 | 4.11.5 | Weld Ports | 32d | 2005-07-19 | 2005-08-31 | 258d | 0d | start no later than 2005-07-19 |  |  |  |  |  |
| 46 | 4.11.6 | Final Machine (not required) | 15d | 2005-08-12 | 2005-09-01 | 276d | 0d | finish no later than 2005-09-01 |  |  |  |  |  |
| 47 | 4.11.7 | Vacuum Test | 14d | 2005-09-01 | 2005-09-20 | 290d | 0d | start no later than 2005-09-01 |  |  |  |  |  |
| 48 | 4.11.8 | Cut Off Ports | 15d | 2005-09-20 | 2005-10-11 | 304d | 0d | start no later than 2005-09-20 |  |  |  |  |  |
| 49 | 4.11.9 | Pack for Shipping #1 | 3d | 2005-10-11 | 2005-10-14 | 319d | 0d | start no later than 2005-10-11 |  |  |  |  |  |
| 50 | 4.11.10 | Receive at PPPL | 3d | 2005-10-14 | 2005-10-19 | 322d | 0d | start no later than 2005-10-14 |  | 375.56 |  |  |  |

| ID | WBS | Task | Duration | Start | Finish | Predecessors | Total slack | Free slack | Constraint | Text1 |
| --- | --- | --- | --- | --- | --- | --- | --- | --- | --- | --- |
| 51 | 4.12 | **Second 120 deg seg QLI# 3 Lot # 2** | 154d | 2005-06-07 | 2006-01-06 |  | 228d | 0d | as late as possible |  |
| 52 | 4.12.1 | 60 deg segment | 20d | 2005-06-07 | 2005-07-04 |  | 228d | 0d | as late as possible |  |
| 53 | 4.12.2 | 60 deg segment | 20d | 2005-06-24 | 2005-07-21 | 52FS-7d | 228d | 0d | as late as possible |  |
| 54 | 4.12.3 | Join two pieces | 15d | 2005-07-22 | 2005-08-11 | 53 | 228d | 0d | as late as possible | 350 |
| 55 | 4.12.4 | Machine for Ports | 20d | 2005-08-12 | 2005-09-08 | 54 | 228d | 0d | as late as possible |  |
| 56 | 4.12.5 | Weld Ports | 25d | 2005-09-09 | 2005-10-13 | 55 | 228d | 0d | as late as possible |  |
| 57 | 4.12.6 | Final Machine (not required) | 15d | 2005-12-19 | 2006-01-06 |  | 367d | 0d | as late as possible |  |
| 58 | 4.12.7 | Vacuum Test | 10d | 2005-10-14 | 2005-10-27 | 56 | 228d | 0d | as late as possible |  |
| 59 | 4.12.8 | Cut Off Ports | 15d | 2005-10-28 | 2005-11-17 | 58 | 228d | 0d | as late as possible |  |
| 60 | 4.12.9 | Pack for Shipping #2 | 4d | 2005-11-18 | 2005-11-23 | 59 | 228d | 0d | as late as possible |  |
| 61 | 4.12.10 | Receive at PPPL | 2d | 2005-11-24 | 2005-11-25 | 60 | 228d | 0d | start no later than 2005-11-24 | 375 |
| 62 | 4.13 | **Third 120 deg seg QLI# 3 Lot # 3** | 133d | 2005-07-06 | 2006-01-06 |  | 240d | 0d | as late as possible |  |
| 63 | 4.13.1 | 60 deg segment | 21d | 2005-07-06 | 2005-08-03 | 52 | 229d | 0d | as late as possible |  |
| 64 | 4.13.2 | 60 deg segment | 20d | 2005-07-26 | 2005-08-22 | 63FS-7d | 229d | 0d | as late as possible |  |
| 65 | 4.13.3 | Join two pieces | 15d | 2005-08-23 | 2005-09-12 | 64 | 229d | 0d | as late as possible | 375 |
| 66 | 4.13.4 | Machine for Ports | 18d | 2005-09-13 | 2005-10-06 | 65 | 229d | 0d | as late as possible |  |
| 67 | 4.13.5 | Weld Ports | 25d | 2005-10-07 | 2005-11-10 | 66 | 229d | 0d | as late as possible |  |
| 68 | 4.13.6 | Final Machine (not required) | 10d | 2005-12-26 | 2006-01-06 |  | 372d | 0d | as late as possible |  |
| 69 | 4.13.7 | Vacuum Test | 10d | 2005-11-11 | 2005-11-24 | 67 | 229d | 0d | as late as possible |  |
| 70 | 4.13.8 | Cut Off Ports | 15d | 2005-11-25 | 2005-12-15 | 69 | 229d | 0d | as late as possible |  |
| 71 | 4.13.9 | Pack for Shipping #3 | 3d | 2005-12-16 | 2005-12-20 | 70 | 229d | 0d | as late as possible |  |
| 72 | 4.13.10 | Receive at PPPL | 2d | 2005-12-21 | 2005-12-22 | 71 | 229d | 0d | as late as possible | 375 |
| 73 | 5 | Pack for PPPL Tooling | 3d | 2005-12-22 | 2005-12-27 | 72 | 229d | 0d | start no later than 2005-12-22 |  |
| 74 | 6 | Receive at PPPL Tooling | 2d? | 2005-12-28 | 2005-12-29 | 73 | 229d | 0d | finish no later than 2005-12-29 | 486 |
