# MTM VVSA

Schedule from MS Project, 2004-07-22 to 2005-11-14, costs in $.
PPPL

## Calendars

- Standard: Mon-Fri 08:00-12:00, 13:00-17:00; Sat-Sun off.

## Schedule

| ID | WBS | Task | Duration | Start | Finish | Total slack | Constraint | Cost |
| --- | --- | --- | --- | --- | --- | --- | --- | --- |
| 1 | 1 | Submit Proposal | 1d? | 2004-07-22 | 2004-07-22 | 342d | finish no earlier than 2004-07-22 |  |
| 2 | 2 | Proposal Discussion | 1d? | 2004-07-26 | 2004-07-26 | 340d | finish no earlier than 2004-07-26 |  |
| 3 | 3 | Receive Order | 12d? | 2004-08-31 | 2004-09-15 | 303d | finish no earlier than 2004-09-15 |  |
| 4 | 4 | Start Up/Engineering | 88d? | 2004-08-31 | 2004-12-30 | 227d | start no earlier than 2004-08-31 |  |
| 5 | 5 | Process Order | 88d? | 2004-08-31 | 2004-12-30 | 227d | start no earlier than 2004-08-31 |  |
| 6 | 6 | Special Tooling LI #2 | 75d? | 2004-09-06 | 2004-12-17 | 236d | start no earlier than 2004-09-06 |  |
| 7 | 7 | Dies | 75d? | 2004-09-06 | 2004-12-17 | 236d | start no earlier than 2004-09-06 |  |
| 8 | 8 | Engineering | 34d? | 2004-09-06 | 2004-10-21 | 277d | start no earlier than 2004-09-06 |  |
| 9 | 9 | Procure Material (4 sets) | 29d? | 2004-09-13 | 2004-10-21 | 277d | start no earlier than 2004-09-13 | 215 |
| 10 | 10 | Vessel Material Procured | 1d? | 2004-11-05 | 2004-11-05 | 266d | start no earlier than 2004-11-05 | 290 |
| 11 | 11 | Machine complete | 39d? | 2004-10-08 | 2004-12-01 | 248d | start no earlier than 2004-10-08 |  |
| 12 | 12 | Deburr | 3d? | 2004-12-02 | 2004-12-06 | 245d | start no earlier than 2004-12-02 |  |
| 13 | 13 | Inspection (Dies Manufactured) | 8d? | 2004-12-08 | 2004-12-17 | 236d | start no earlier than 2004-12-08 | 464 |
| 14 | 14 | Fixtures (2 sets) | 66d? | 2004-09-06 | 2004-12-06 | 245d | start no earlier than 2004-09-06 |  |
| 15 | 15 | Engineering | 44d? | 2004-09-06 | 2004-11-04 | 267d | start no earlier than 2004-09-06 |  |
| 16 | 16 | Procure Material | 19d? | 2004-09-13 | 2004-10-07 | 287d | start no earlier than 2004-09-13 | 220 |
| 17 | 17 | Machine complete | 29d? | 2004-10-11 | 2004-11-18 | 257d | start no earlier than 2004-10-11 |  |
| 18 | 18 | Assemble | 4d? | 2004-11-22 | 2004-11-25 | 252d | start no earlier than 2004-11-22 |  |
| 19 | 19 | Deburr | 2d? | 2004-11-26 | 2004-11-29 | 250d | start no earlier than 2004-11-26 |  |
| 20 | 20 | Inspection | 4d? | 2004-12-01 | 2004-12-06 | 245d | start no earlier than 2004-12-01 |  |
| 21 | 21 | Development Panels (9 panels) | 44d? | 2004-11-19 | 2005-01-19 | 213d | start no earlier than 2004-11-19 |  |
| 22 | 22 | Production Panels (9-18 panels) 1/3 Formed | 27d? | 2005-01-20 | 2005-02-25 | 186d | start no earlier than 2005-01-20 | 260 |
| 23 | 23 | 2nd 1/3 Formed | 1d? | 2004-11-05 | 2004-11-05 | 266d |  | 200 |
| 24 | 24 | Production Panels (36-45 panels) 3rd 1/3 Formed | 50d? | 2005-02-28 | 2005-05-06 | 136d | start no earlier than 2005-02-28 | 200 |
| 25 | 25 | First 120 deg seg LI #3 | 162d? | 2005-01-20 | 2005-09-02 | 51d | start no earlier than 2005-01-20 |  |
| 26 | 26 | 1st 60 deg segment | 65d? | 2005-01-20 | 2005-04-20 | 148d | start no earlier than 2005-01-20 |  |
| 27 | 27 | 2nd 60 deg segment | 38d? | 2005-02-28 | 2005-04-20 | 148d | start no earlier than 2005-02-28 |  |
| 28 | 28 | Join 2 pieces (First VVSA fabricated) | 20d? | 2005-04-21 | 2005-05-18 | 128d | start no earlier than 2005-04-21 | 375 |
| 29 | 29 | Machine for ports | 14d? | 2005-05-19 | 2005-06-07 | 114d | start no earlier than 2005-05-19 |  |
| 30 | 30 | Weld ports | 15d? | 2005-06-08 | 2005-06-28 | 99d | start no earlier than 2005-06-08 |  |
| 31 | 31 | Final Machine | 17d? | 2005-06-29 | 2005-07-21 | 82d | start no earlier than 2005-06-29 |  |
| 32 | 32 | Vacuum Test | 10d? | 2005-07-22 | 2005-08-04 | 72d | start no earlier than 2005-07-22 |  |
| 33 | 33 | Cut off Ports | 15d? | 2005-08-05 | 2005-08-25 | 57d | start no earlier than 2005-08-05 |  |
| 34 | 34 | Pack for ShippingLI# 4 | 4d? | 2005-08-26 | 2005-08-31 | 53d | start no earlier than 2005-08-26 |  |
| 35 | 35 | Receive at PPPL | 2d? | 2005-09-01 | 2005-09-02 | 51d | start no earlier than 2005-09-01 |  |
| 36 | 36 | Second 120 Deg Seg LI #3 | 108d? | 2005-04-21 | 2005-09-19 | 40d | start no earlier than 2005-04-21 |  |
| 37 | 37 | 1st 60 deg segment | 35d? | 2005-04-21 | 2005-06-08 | 113d | start no earlier than 2005-04-21 |  |
| 38 | 38 | 2nd 60 deg segment | 35d? | 2005-04-21 | 2005-06-08 | 113d | start no earlier than 2005-04-21 |  |
| 39 | 39 | Join 2 pieces (Second VVSA fabricated) | 12d? | 2005-06-09 | 2005-06-24 | 101d | start no earlier than 2005-06-09 | 350 |
| 40 | 40 | Machine for ports | 10d? | 2005-06-27 | 2005-07-08 | 91d | start no earlier than 2005-06-27 |  |
| 41 | 41 | Weld ports | 17d? | 2005-07-11 | 2005-08-02 | 74d | start no earlier than 2005-07-11 |  |
| 42 | 42 | Final Machine | 12d? | 2005-08-03 | 2005-08-18 | 62d | start no earlier than 2005-08-03 |  |
| 43 | 43 | Vacuum Test | 5d? | 2005-08-19 | 2005-08-25 | 57d | start no earlier than 2005-08-19 |  |
| 44 | 44 | Cut off Ports | 12d? | 2005-08-26 | 2005-09-12 | 45d | start no earlier than 2005-08-26 |  |
| 45 | 45 | Pack for ShippingLI# 4 | 3d? | 2005-09-13 | 2005-09-15 | 42d | start no earlier than 2005-09-13 |  |
| 46 | 46 | Receive at PPPL | 2d? | 2005-09-16 | 2005-09-19 | 40d | start no earlier than 2005-09-16 |  |
| 47 | 47 | Third 120 Deg Seg LI #3 | 98d? | 2005-06-09 | 2005-10-24 | 15d | start no earlier than 2005-06-09 |  |
| 48 | 48 | 1st 60 deg segment | 35d? | 2005-06-09 | 2005-07-27 | 78d | start no earlier than 2005-06-09 |  |
| 49 | 49 | 2nd 60 deg segment | 35d? | 2005-06-09 | 2005-07-27 | 78d | start no earlier than 2005-06-09 |  |
| 50 | 50 | Join 2 pieces (Third VVSA fabricated) | 10d? | 2005-07-28 | 2005-08-10 | 68d | start no earlier than 2005-07-28 | 350 |
| 51 | 51 | Machine for ports | 8d? | 2005-08-11 | 2005-08-22 | 60d | start no earlier than 2005-08-11 |  |
| 52 | 52 | Weld ports | 15d? | 2005-08-23 | 2005-09-12 | 45d | start no earlier than 2005-08-23 |  |
| 53 | 53 | Final Machine | 10d? | 2005-09-13 | 2005-09-26 | 35d | start no earlier than 2005-09-13 |  |
| 54 | 54 | Vacuum Test | 5d? | 2005-09-27 | 2005-10-03 | 30d | start no earlier than 2005-09-27 |  |
| 55 | 55 | Cut off Ports | 10d? | 2005-10-04 | 2005-10-17 | 20d | start no earlier than 2005-10-04 |  |
| 56 | 56 | Pack for ShippingLI# 4 | 3d? | 2005-10-18 | 2005-10-20 | 17d | start no earlier than 2005-10-18 |  |
| 57 | 57 | Receive at PPPL | 2d? | 2005-10-21 | 2005-10-24 | 15d | start no earlier than 2005-10-21 |  |
| 58 | 58 | Receipt/Acceptance by PPPL of 1st VVSA | 233d? | 2004-11-05 | 2005-09-27 | 34d | start no earlier than 2004-11-05 | 375.56 |
| 59 | 59 | Receipt/Acceptance by PPPL of 2nd VVSA | 255d? | 2004-11-05 | 2005-10-27 | 12d | start no earlier than 2004-11-05 | 375 |
| 60 | 60 | Receipt/Acceptance by PPPL of 3rd VVSA | 255d? | 2004-11-05 | 2005-10-27 | 12d | start no earlier than 2004-11-05 | 375 |
| 61 | 61 | Delivery to PPPL of Tooling | 267d? | 2004-11-05 | 2005-11-14 | 0d | start no earlier than 2004-11-05 | 486 |
| 63 | 62 | TOTAL | 1d? | 2005-10-27 | 2005-10-27 | 12d | finish no earlier than 2005-10-27 |  |
