# Order 65511 Bell PO# 219520 061804test

Schedule from MS Project, 2004-07-22 to 2005-10-28, scheduled back from the finish.
Major Tool and Machine, Inc.

## Calendars

- Standard: Mon-Fri 08:00-12:00, 13:00-17:00; Sat-Sun off.

## Resources

| Resource |
| --- |
| 2 |
| 3 |
| 4 |
| 5 |

## Schedule

| ID | WBS | Task | Type | Duration | Start | Finish | Total slack | Free slack | Constraint | Text1 |
| --- | --- | --- | --- | --- | --- | --- | --- | --- | --- | --- |
| 1 | 1 | Submit Proposal | milestone | 0d | 2004-07-22 | 2004-07-22 | 0d |  | start no later than 2004-07-22 |  |
| 2 | 2 | Teleconference to discuss Proposal |  | 5d | 2004-07-26 | 2004-07-30 | 2d | 0d | start no later than 2004-07-26 |  |
| 3 | 3 | Receive Order |  | 1d | 2004-08-31 | 2004-08-31 | 28d | 0d | finish no later than 2004-08-31 |  |
| 4 | 4 | **Start Up/Engineering LI#1** |  | 103d? | 2004-07-22 | 2004-12-13 | 0d |  | as late as possible |  |
| 5 | 4.1 | Process Order |  | 75d | 2004-08-31 | 2004-12-13 | 28d | 0d | start no later than 2004-08-31 |  |
| 6 | 4.2 | Sect 5.1.3 Proc Outline & Asc Procedures |  | 1d? | 2004-07-22 | 2004-07-22 | 0d |  | finish no later than 2004-07-22 | 95 |
| 7 | 5 | **Special Tooling LI# 2** |  | 332d? | 2004-07-22 | 2005-10-28 | 0d |  | as late as possible |  |
| 8 | 5.1 | **Dies** |  | 300d? | 2004-09-06 | 2005-10-28 | 32d | 0d | as late as possible |  |
| 9 | 5.1.1 | Engineering |  | 35d | 2004-09-06 | 2004-10-22 | 32d | 0d | start no later than 2004-09-06 |  |
| 10 | 5.1.2 | Sect 5.1 Segmentation Scheme |  | 2d? | 2005-10-27 | 2005-10-28 | 330d | 0d | start no later than 2005-10-27 | 75 |
| 11 | 5.1.3 | Procure Materials (4 sets) |  | 6w | 2004-09-13 | 2004-10-22 | 37d | 0d | start no later than 2004-09-13 | 215 |
| 12 | 5.1.4 | Machine Complete |  | 8w | 2004-10-08 | 2004-12-02 | 56d | 0d | start no later than 2004-10-08 |  |
| 13 | 5.1.5 | Deburr |  | 4d | 2004-12-02 | 2004-12-07 | 95d | 0d | start no later than 2004-12-02 |  |
| 14 | 5.1.6 | Inspection |  | 9d | 2004-12-08 | 2004-12-20 | 99d | 0d | start no later than 2004-12-08 | 239 |
| 15 | 5.2 | **Fixtures (2) 60 degree** |  | 67d | 2004-09-06 | 2004-12-07 | 32d | 0d | as late as possible |  |
| 16 | 5.2.1 | Engineering |  | 45d | 2004-09-06 | 2004-11-05 | 32d | 0d | start no later than 2004-09-06 |  |
| 17 | 5.2.2 | Procure Materials |  | 4w | 2004-09-13 | 2004-10-08 | 37d | 0d | start no later than 2004-09-13 |  |
| 18 | 5.2.3 | Machine Complete |  | 6w | 2004-10-11 | 2004-11-19 | 57d | 0d | start no later than 2004-10-11 |  |
| 19 | 5.2.4 | Assemble |  | 1w | 2004-11-22 | 2004-11-26 | 87d | 0d | start no later than 2004-11-22 |  |
| 20 | 5.2.5 | Deburr |  | 3d | 2004-11-26 | 2004-11-30 | 91d | 0d | start no later than 2004-11-26 |  |
| 21 | 5.2.6 | Inspection |  | 5d | 2004-12-01 | 2004-12-07 | 94d | 0d | start no later than 2004-12-01 |  |
| 22 | 5.3 | **Fixture (1) 120 degree** |  | 0d | 2004-07-22 | 2004-07-22 | 0d |  | as late as possible |  |
| 23 | 5.3.1 | Engineering | milestone | 0d | 2004-07-22 | 2004-07-22 | 0d |  | start no later than 2004-07-22 |  |
| 24 | 5.3.2 | Procure Materials | milestone | 0d | 2004-07-22 | 2004-07-22 | 0d |  | start no later than 2004-07-22 | 220 |
| 25 | 5.3.3 | Machine Complete | milestone | 0d | 2004-07-22 | 2004-07-22 | 0d |  | start no later than 2004-07-22 |  |
| 26 | 5.3.4 | Assemble | milestone | 0d | 2004-07-22 | 2004-07-22 | 0d |  | start no later than 2004-07-22 |  |
| 27 | 5.3.5 | Deburr | milestone | 0d | 2004-07-22 | 2004-07-22 | 0d |  | start no later than 2004-07-22 |  |
| 28 | 5.3.6 | Inspection | milestone | 0d | 2004-07-22 | 2004-07-22 | 0d |  | start no later than 2004-07-22 |  |
| 29 | 6 | Sect 5.1.2 Fiducials |  | 1d? | 2004-07-22 | 2004-07-22 | 0d |  | finish no later than 2004-07-22 | 55 |
| 30 | 7 | Procure Vessel Material |  | 1d? | 2004-07-22 | 2004-07-22 | 0d |  | finish no later than 2004-07-22 | 290 |
| 31 | 8 | Development Panels (9 panels) | milestone | 0d | 2005-10-28 | 2005-10-28 | 332d | 0d | as late as possible | 260 |
| 32 | 9 | Production Panels (9-18 panels) | milestone | 0d | 2005-10-28 | 2005-10-28 | 332d | 0d | as late as possible | 200 |
| 33 | 10 | Production Panels (36-45 panels) | milestone | 0d | 2005-10-28 | 2005-10-28 | 332d | 0d | as late as possible | 200 |

| ID | WBS | Task | Duration | Start | Finish | Total slack | Free slack | Constraint | Text1 |
| --- | --- | --- | --- | --- | --- | --- | --- | --- | --- |
| 34 | 11 | **First 120 deg seg LI #3** | 162d | 2005-01-20 | 2005-09-05 | 131d | 0d | as late as possible |  |
| 35 | 11.1 | 1st 60 deg segment | 65d | 2005-01-20 | 2005-04-21 | 131d | 0d | start no later than 2005-01-20 |  |
| 36 | 11.2 | 2nd 60 deg segment | 39d | 2005-02-28 | 2005-04-21 | 157d | 0d | start no later than 2005-02-28 |  |
| 37 | 11.3 | Join two pieces | 20d | 2005-04-21 | 2005-05-19 | 196d | 0d | start no later than 2005-04-21 | 350 |
| 38 | 11.4 | Machine for Ports | 14d | 2005-05-19 | 2005-06-08 | 216d | 0d | start no later than 2005-05-19 |  |
| 39 | 11.5 | Weld Ports | 15d | 2005-06-08 | 2005-06-29 | 230d | 0d | start no later than 2005-06-08 |  |
| 40 | 11.6 | Final Machine | 17d | 2005-06-29 | 2005-07-22 | 245d | 0d | start no later than 2005-06-29 |  |
| 41 | 11.7 | Vacuum Test | 10d | 2005-07-22 | 2005-08-05 | 262d | 0d | start no later than 2005-07-22 |  |
| 42 | 11.8 | Cut Off Ports | 15d | 2005-08-05 | 2005-08-26 | 272d | 0d | start no later than 2005-08-05 |  |
| 43 | 11.9 | Pack for Shipping LI#4 | 4d | 2005-08-26 | 2005-09-01 | 287d | 0d | start no later than 2005-08-26 |  |
| 44 | 11.10 | Receive at PPPL | 2d | 2005-09-01 | 2005-09-05 | 291d | 0d | start no later than 2005-09-01 | 375.56 |
| 45 | 12 | **Second 120 deg seg LI# 3** | 108d | 2005-04-21 | 2005-09-20 | 196d | 0d | as late as possible |  |
| 46 | 12.1 | 60 deg segment | 35d | 2005-04-21 | 2005-06-09 | 196d | 0d | start no later than 2005-04-21 |  |
| 47 | 12.2 | 60 deg segment | 35d | 2005-04-21 | 2005-06-09 | 196d | 0d | start no later than 2005-04-21 |  |
| 48 | 12.3 | Join two pieces | 12d | 2005-06-09 | 2005-06-27 | 231d | 0d | start no later than 2005-06-09 | 350 |
| 49 | 12.4 | Machine for Ports | 10d | 2005-06-27 | 2005-07-11 | 243d | 0d | start no later than 2005-06-27 |  |
| 50 | 12.5 | Weld Ports | 17d | 2005-07-11 | 2005-08-03 | 253d | 0d | start no later than 2005-07-11 |  |
| 51 | 12.6 | Final Machine | 12d | 2005-08-03 | 2005-08-19 | 270d | 0d | start no later than 2005-08-03 |  |
| 52 | 12.7 | Vacuum Test | 5d | 2005-08-19 | 2005-08-26 | 282d | 0d | start no later than 2005-08-19 |  |
| 53 | 12.8 | Cut Off Ports | 12d | 2005-08-26 | 2005-09-13 | 287d | 0d | start no later than 2005-08-26 |  |
| 54 | 12.9 | Pack for Shipping LI#4 | 3d | 2005-09-13 | 2005-09-16 | 299d | 0d | start no later than 2005-09-13 |  |
| 55 | 12.10 | Receive at PPPL | 2d | 2005-09-16 | 2005-09-20 | 302d | 0d | start no later than 2005-09-16 | 375 |
| 56 | 13 | **Third 120 deg seg LI# 3** | 101d? | 2005-06-09 | 2005-10-28 | 231d | 0d | as late as possible |  |
| 57 | 13.1 | 60 deg segment | 35d | 2005-06-09 | 2005-07-28 | 231d | 0d | start no later than 2005-06-09 |  |
| 58 | 13.2 | 60 deg segment | 35d | 2005-06-09 | 2005-07-28 | 231d | 0d | start no later than 2005-06-09 |  |
| 59 | 13.3 | Join two pieces | 10d | 2005-07-28 | 2005-08-11 | 266d | 0d | start no later than 2005-07-28 | 375 |
| 60 | 13.4 | Machine for Ports | 8d | 2005-08-11 | 2005-08-23 | 276d | 0d | start no later than 2005-08-11 |  |
| 61 | 13.5 | Weld Ports | 15d | 2005-08-23 | 2005-09-13 | 284d | 0d | start no later than 2005-08-23 |  |
| 62 | 13.6 | Final Machine | 10d | 2005-09-13 | 2005-09-27 | 299d | 0d | start no later than 2005-09-13 |  |
| 63 | 13.7 | Vacuum Test | 5d | 2005-09-27 | 2005-10-04 | 309d | 0d | start no later than 2005-09-27 |  |
| 64 | 13.8 | Cut Off Ports | 10d | 2005-10-04 | 2005-10-18 | 314d | 0d | start no later than 2005-10-04 |  |
| 65 | 13.9 | Pack for Shipping LI#4 | 3d | 2005-10-18 | 2005-10-21 | 324d | 0d | start no later than 2005-10-18 |  |
| 66 | 13.10 | Receive at PPPL | 2d | 2005-10-21 | 2005-10-25 | 327d | 0d | start no later than 2005-10-21 | 375 |
| 67 | 13.11 | Pack for PPPL Tooling | 1d? | 2005-10-28 | 2005-10-28 | 331d | 0d | as late as possible |  |
| 68 | 13.12 | Receive at PPPL Tooling | 1d? | 2005-10-28 | 2005-10-28 | 331d | 0d | as late as possible | 486 |
